# TIEMPO TRABAJO ACT_CRON 3 MESES FINALES PRECONSTRUCCIÓN V2

Schedule from MS Project, 2021-03-06 to 2021-06-05.

## Calendars

- Estándar: Mon-Sun 07:00-12:00, 13:00-17:00. Exceptions (off unless hours are given): 2021-04-01 (Jueves Santo 2021), 2021-04-02 (Viernes Santo 2021), 2021-04-03 (Sabado Santo 2021), 2021-04-04 (Domingo de resurrección 2021).

## Schedule

| ID | WBS | Task | Type | Duration | Start | Finish | Predecessors | Total slack | Free slack |
| --- | --- | --- | --- | --- | --- | --- | --- | --- | --- |
| 1 | 1 | **CRONOGRAMA DE ACTIVIDADES DE DISEÑO Y AUSCULTACIÓN - CALLE LIMA - EL DORADO** |  | 98d | 2021-03-06 | 2021-06-05 |  | 0d |  |
| 2 | 1.1 | APROPIACIÓN DE ESTUDIOS Y DISEÑOS Y DE OBRAS | milestone, manual | 0d | 2021-03-06 | 2021-03-06 |  |  |  |
| 3 | 1.2 | **AJUSTE DE DISEÑOS Y AUSCULTACIÓN DE LAS OBRAS** |  | 98d | 2021-03-06 | 2021-06-05 |  | 0d |  |
| 4 | 1.2.1 | **TOPOGRÁFICO** |  | 30d | 2021-03-08 | 2021-04-07 |  | 1d |  |
| 5 | 1.2.1.1 | Levantamiento Topográfico de las obras existentes para las diferentes especialidades. |  | 30d | 2021-03-08 | 2021-04-07 | 2FS+2d | 1d | 0d |
| 6 | 1.2.1.2 | Notam para topografía en área restringida |  | 8d | 2021-03-19 | 2021-03-26 | 2FS+15d | 0d |  |
| 7 | 1.2.1.3 | Aprobación Topografía por Interventoría | milestone | 0d | 2021-04-07 | 2021-04-07 | 5 | 56d | 33d |
| 8 | 1.2.2 | **METODOLOGÍA BIM** |  | 90d | 2021-03-11 | 2021-06-03 |  | 2d |  |
| 9 | 1.2.2.1 | Integración con modelo BIM |  | 35d | 2021-04-07 | 2021-05-08 | 5, 7FF+2d | 23d | 12d |
| 10 | 1.2.2.2 | Plan de Ejecución BIM-BEP |  | 90d | 2021-03-11 | 2021-06-03 | 5SS+4d | 2d |  |
| 11 | 1.2.3 | **GEOTÉCNICO** |  | 93d | 2021-03-06 | 2021-05-31 |  | 4d |  |
| 12 | 1.2.3.1 | Completar exploración y caracterización |  | 6d | 2021-03-06 | 2021-03-11 | 2 | 4d | 0d |
| 13 | 1.2.3.2 | Ajuste de modelos de cálculo con los datos de la exploración |  | 12d | 2021-03-11 | 2021-03-22 | 12 | 30d | 0d |
| 14 | 1.2.3.3 | Análisis prospectivo de comportamiento de las obras proyectadas: excavación del deprimido, conformación final de vía y pavimentos. |  | 30d | 2021-03-22 | 2021-04-21 | 13, 5FS-15d | 32d | 28d |
| 15 | 1.2.3.4 | Apoyo a las demás disciplinas para aspectos relacionados con interacción suelo estructura, parámetros de diseño estructural. |  | 70d | 2021-03-11 | 2021-05-16 | 12, 14FF | 4d | 0d |
| 16 | 1.2.3.5 | Recomendaciones y consideraciones de flujo y drenaje de aguas subterraneas. |  | 12d | 2021-03-24 | 2021-04-08 | 15SS+15d | 5d | 0d |
| 17 | 1.2.3.6 | Revisiones especialista Geotecnia Interventoría |  | 50d | 2021-03-22 | 2021-05-09 | 13 | 30d | 0d |
| 18 | 1.2.3.7 | Aprobación Estudios Geotécnicos por Interventoría | milestone | 0d | 2021-05-09 | 2021-05-09 | 17 | 30d | 25d |
| 19 | 1.2.3.8 | Recomendaciones y especificaciones de las obras a construir |  | 30d | 2021-03-29 | 2021-04-28 | 15SS+20d | 4d | 0d |
| 20 | 1.2.3.9 | Análisis de cantidades especificas de obra, Especificaciones técnicas y presupesto |  | 60d | 2021-04-08 | 2021-05-31 | 16, 18FF | 5d |  |
| 21 | 1.2.4 | **ESTRUCTURAL** |  | 88d | 2021-03-11 | 2021-06-01 |  | 4d |  |
| 22 | 1.2.4.1 | Verificación de estructuras en campo vs planos |  | 5d | 2021-03-11 | 2021-03-15 | 5SS+4d | 7d | 0d |
| 23 | 1.2.4.2 | **Ensayos de campo destructivos y no destructivos para Auscultación** |  | 16d | 2021-03-16 | 2021-03-30 |  | 7d |  |
| 24 | 1.2.4.2.1 | Toma de núcleos y ensayo de nucleos |  | 12d | 2021-03-16 | 2021-03-26 | 22 | 7d | 0d |
| 25 | 1.2.4.2.2 | Ensayos identificación de refuerzo |  | 4d | 2021-03-26 | 2021-03-30 | 24 | 7d | 3d |
| 26 | 1.2.4.3 | Análisis de la información entregada por las demás especialidades (Vías, geotecnia, hidráulica) |  | 8d | 2021-03-29 | 2021-04-09 | 19SS | 4d | 0d |
| 27 | 1.2.4.4 | Análisis del sistema estructural total y estructuras existentes para definir si se debe repotenciar o modificar, o ninguna de las anteriores |  | 18d | 2021-03-31 | 2021-04-20 | 22SS+2d, 26SS+2d, 24SS+2d, 25SS+2d | 4d | 0d |
| 28 | 1.2.4.5 | Diseño de la repotenciación o modificaciones requeridas Deprimido |  | 12d | 2021-04-17 | 2021-04-28 | 27SS+15d | 4d | 0d |
| 29 | 1.2.4.6 | Elaboración de planos e informes de las estructuras principales faltantes (vigas puntales y placa aérea) |  | 15d | 2021-04-26 | 2021-05-09 | 28SS+10d, 10SS+10d | 4d | 0d |
| 30 | 1.2.4.7 | Análisis y diseño de estructuras requeridas para redes hidráulicas, eléctricas, geotecnia, y otras especialidades |  | 15d | 2021-04-09 | 2021-04-22 | 26 | 23d | 19d |
| 31 | 1.2.4.8 | Revisiones especialista Estructural Interventoría |  | 45d | 2021-04-08 | 2021-05-18 | 27SS+5d | 17d | 0d |
| 32 | 1.2.4.9 | Aprobación Estudios Estructurales por Interventoría | milestone | 0d | 2021-05-20 | 2021-05-20 | 31FS+2d | 17d | 13d |
| 33 | 1.2.4.10 | Análisis de cantidades especificas de obra, Especificaciones técnicas y presupesto |  | 25d | 2021-05-09 | 2021-05-31 | 29, 19FS-5d, 30, 32FF | 4d | 0d |
| 34 | 1.2.4.11 | Entrega Final Estructural | milestone | 0d | 2021-06-01 | 2021-06-01 | 33FS+1d | 4d |  |

| ID | WBS | Task | Type | Duration | Start | Finish | Predecessors | Total slack | Free slack |
| --- | --- | --- | --- | --- | --- | --- | --- | --- | --- |
| 35 | 1.2.5 | **DISEÑO GEOMÉTRICO** |  | 85d | 2021-03-16 | 2021-06-04 |  | 1d |  |
| 36 | 1.2.5.1 | TOPOGRAFÍA (Planificación, revisión de carteras, digitalización del modelo) |  | 15d | 2021-03-16 | 2021-03-30 | 5SS+10d, 6FF | 1d | 0d |
| 37 | 1.2.5.2 | GEOMETRÍA HORIZONTAL para calle de rodaje, Deprimido, Box-Culvert y ajustes por solicitud de interventoría u otra especialidad |  | 15d | 2021-03-21 | 2021-04-07 | 36SS+5d | 1d | 0d |
| 38 | 1.2.5.3 | GEOMETRÍA VERTICAL para calle de rodaje, Deprimido, Box-Culvert y ajustes por solicitud de interventoría u otra especialidad |  | 15d | 2021-03-25 | 2021-04-12 | 36SS+10d | 27d | 0d |
| 39 | 1.2.5.4 | Planos Geométricos |  | 35d | 2021-04-18 | 2021-05-19 | 37SS+2d, 9SS, 46SS-5d | 11d | 0d |
| 40 | 1.2.5.5 | Informes Geométricos |  | 35d | 2021-04-07 | 2021-05-08 | 36SS+20d | 1d | 0d |
| 41 | 1.2.5.6 | Revisiones especialista Geométrico Interventoría |  | 50d | 2021-03-30 | 2021-05-17 | 37SS+10d | 1d | 0d |
| 42 | 1.2.5.7 | Aprobación Estudios Diseño Geométrico por Interventoría | milestone | 0d | 2021-05-22 | 2021-05-22 | 41FS+5d | 1d | 0d |
| 43 | 1.2.5.8 | Cáclulo cantidades de obra, Especificaciones técnicas y presupesto |  | 30d | 2021-05-08 | 2021-06-04 | 39SS+5d, 40, 42FS-15d | 1d |  |
| 44 | 1.2.6 | **SEÑALIZACIÓN HORIZONTAL Y VERTICAL** |  | 34d | 2021-04-12 | 2021-05-12 |  | 27d |  |
| 45 | 1.2.6.1 | AYUDAS VISUALES PARA NAVEGACION AEREA y ajustes por solicitud de interventoría u otra especialidad |  | 12d | 2021-04-12 | 2021-04-22 | 38 | 27d | 0d |
| 46 | 1.2.6.2 | Revisión de Señalización via de servicio a desnivel |  | 12d | 2021-04-22 | 2021-05-03 | 38, 45 | 27d | 0d |
| 47 | 1.2.6.3 | Aprobación Estudios Diseño Señalización por Interventoría | milestone | 0d | 2021-05-03 | 2021-05-03 | 46 | 37d |  |
| 48 | 1.2.6.4 | Cálculo de cantidades de obra, Especificaciones técnicas y presupesto Señalización |  | 10d | 2021-05-03 | 2021-05-12 | 46 | 27d |  |
| 49 | 1.2.7 | **HIDRÁULICO** |  | 91d | 2021-03-11 | 2021-06-04 |  | 1d |  |
| 50 | 1.2.7.1 | **AUSCULTACIÓN HIDRAULICA - Recopilación de información Obra Construida** |  | 40d | 2021-03-11 | 2021-04-20 |  | 1d |  |
| 51 | 1.2.7.1.1 | Observación y Valoración Conductos y Tunel Liner (hidráulica, Estructuras, Geotecnia) |  | 10d | 2021-03-11 | 2021-03-20 | 5SS+4d | 1d | 0d |
| 52 | 1.2.7.1.2 | Pruebas hidráulicas en Tunel Liner |  | 15d | 2021-03-24 | 2021-04-11 | 51FS+5d | 1d | 0d |
| 53 | 1.2.7.1.3 | Ajuste de actividades según pruebas hidráulicas |  | 10d | 2021-04-11 | 2021-04-20 | 52 | 1d | 0d |
| 54 | 1.2.7.2 | **PLAN DE CONTINGENCIA - Recopilación de información Disponible Relacionada** |  | 62d | 2021-03-14 | 2021-05-12 |  | 11d |  |
| 55 | 1.2.7.2.1 | Depuración y Análisis de Información Disponible |  | 12d | 2021-03-14 | 2021-03-24 | 51SS+3d | 15d | 0d |
| 56 | 1.2.7.2.2 | Linea Base Actual Area de Trabajo / Poligonos Generadores (Bombeos, estructuras, PTAR, Lagunas) e inventario de obra construida |  | 15d | 2021-03-24 | 2021-04-11 | 51, 55 | 15d | 0d |
| 57 | 1.2.7.2.3 | Incorporación de diseños relacionados |  | 25d | 2021-03-24 | 2021-04-20 | 15SS+15d | 11d | 10d |
| 58 | 1.2.7.2.4 | Replanteos / Ajuste a Procedimientos Constructivos y Ambiental |  | 45d | 2021-03-23 | 2021-05-06 | 55SS+10d | 18d | 17d |
| 59 | 1.2.7.2.5 | Elaboración de Plan de contingencia y Procedimiento Constructivo |  | 25d | 2021-04-20 | 2021-05-12 | 58SS+10d, 53, 57SS+15d | 1d | 0d |

| ID | WBS | Task | Type | Duration | Start | Finish | Predecessors | Total slack | Free slack |
| --- | --- | --- | --- | --- | --- | --- | --- | --- | --- |
| 60 | 1.2.7.3 | **EVALUACION DE REDES - Catastro de Redes / Topografia** |  | 50d | 2021-03-24 | 2021-05-12 |  | 1d |  |
| 61 | 1.2.7.3.1 | Evaluacion Redes Existentes (Accesorios Bombeo, linea sanitaria 14", Contraincendios 10", Ingreso lagunas, ingreso PTAR) |  | 20d | 2021-03-24 | 2021-04-15 | 51FS+5d | 24d | 23d |
| 62 | 1.2.7.3.2 | Integracion a Solución Obras de Desvio, Plan de Contingencia y Procedimiento Constructivo |  | 25d | 2021-04-20 | 2021-05-12 | 61SS+2d, 59SS | 1d | 0d |
| 63 | 1.2.7.4 | Revisiones especialista Hidráulico Interventoría |  | 45d | 2021-04-11 | 2021-05-21 | 56SS+15d | 15d | 0d |
| 64 | 1.2.7.5 | Aprobación Estudios Hidráulicos por Interventoría | milestone | 0d | 2021-05-22 | 2021-05-22 | 63FS+2d | 15d |  |
| 65 | 1.2.7.6 | AJUSTE DE PLANOS Y MEMORIAS DE CÁLCULO (Desvío, drenaje general, drenaje deprimido y red contraincendio) |  | 25d | 2021-05-03 | 2021-05-25 | 62SS+15d | 1d | 0d |
| 66 | 1.2.7.7 | CANTIDADES DE OBRA Y ESPECIFICACIONES (Obras de desvío, drenaje general, drenaje deprimido y red contraincendio) |  | 36d | 2021-05-03 | 2021-06-04 | 65SS | 1d |  |
| 67 | 1.2.8 | **PAVIMENTOS** |  | 90d | 2021-03-12 | 2021-06-04 |  | 1d |  |
| 68 | 1.2.8.1 | Evaluación de Información faltante de diseños |  | 7d | 2021-03-12 | 2021-03-18 | 5SS+5d | 17d |  |
| 69 | 1.2.8.2 | Notam para trabajos de campo pavimentos en área restringida |  | 8d | 2021-03-26 | 2021-04-06 | 6 | 0d |  |
| 70 | 1.2.8.3 | **Trabajos de campo** |  | 16d | 2021-04-06 | 2021-04-20 | 68, 69 | 0d |  |
| 71 | 1.2.8.3.1 | Auscultación pavimento existente |  | 8d | 2021-04-06 | 2021-04-13 | 69 | 0d |  |
| 72 | 1.2.8.3.2 | Toma de muestras pavimento existente |  | 4d | 2021-04-15 | 2021-04-19 | 69, 71FS+2d | 0d |  |
| 73 | 1.2.8.3.3 | Sondeos |  | 2d | 2021-04-19 | 2021-04-20 | 69, 72 | 0d |  |
| 74 | 1.2.8.4 | Ensayos de laboratorio |  | 15d | 2021-04-21 | 2021-05-04 | 70FS-5d, 72, 73 | 0d |  |
| 75 | 1.2.8.5 | Ajuste/actualización de diseños |  | 12d | 2021-05-04 | 2021-05-14 | 74 | 0d |  |
| 76 | 1.2.8.6 | Elaboración de Informe |  | 15d | 2021-05-15 | 2021-05-28 | 75 | 2d | 0d |
| 77 | 1.2.8.7 | Revisiones especialista Pavimentos Interventoría |  | 25d | 2021-05-10 | 2021-06-01 | 74, 76FF+5d | 2d | 0d |
| 78 | 1.2.8.8 | Aprobación Diseño Pavimentos Geotécnicos por Interventoría | milestone | 0d | 2021-06-03 | 2021-06-03 | 77FS+2d | 2d |  |
| 79 | 1.2.8.9 | Cálculo de cantidades de obra, Especificaciones técnicas y presupesto |  | 28d | 2021-05-10 | 2021-06-04 | 75FS-5d | 0d |  |
| 80 | 1.2.9 | **ELÉCTRICO** |  | 88d | 2021-03-12 | 2021-06-02 |  | 2d |  |
| 81 | 1.2.9.1 | Levantamiento Topográfico (Cajas, canalización y balizamiento existente) |  | 10d | 2021-03-12 | 2021-03-21 | 5SS+5d | 4d | 0d |
| 82 | 1.2.9.2 | Revisión y pruebas balizas Calle Lima |  | 25d | 2021-03-21 | 2021-04-16 | 81 | 4d | 0d |
| 83 | 1.2.9.3 | Auscultación de redes eléctricas y voz y datos existentes |  | 15d | 2021-04-16 | 2021-04-29 | 82 | 4d | 0d |
| 84 | 1.2.9.4 | Informe auscultación redes eléctricas y voz y datos |  | 10d | 2021-04-29 | 2021-05-08 | 83 | 12d | 10d |
| 85 | 1.2.9.5 | Elaboración y Entrega informe del sistema de control y monitoreo |  | 20d | 2021-04-29 | 2021-05-17 | 83 | 16d | 14d |
| 86 | 1.2.9.6 | Red eléctrica bombeo y alumbrado deprimido |  | 15d | 2021-05-16 | 2021-05-30 | 65FS-10d | 2d | 0d |
| 87 | 1.2.9.7 | Revisiones especialista Eléctrico Interventoría |  | 40d | 2021-04-21 | 2021-05-26 | 83SS+5d | 4d | 0d |
| 88 | 1.2.9.8 | Aprobación Diseños Eléctricos por Interventoría | milestone | 0d | 2021-05-28 | 2021-05-28 | 87FS+2d | 4d | 2d |
| 89 | 1.2.9.9 | Entrega de planos finales y Especificaciones |  | 1d | 2021-05-30 | 2021-05-30 | 85, 86, 88 | 2d | 0d |
| 90 | 1.2.9.10 | Cálculo de cantidades y presupuesto |  | 18d | 2021-05-17 | 2021-06-02 | 89FS-15d, 84 | 2d |  |

| ID | WBS | Task | Type | Duration | Start | Finish | Predecessors | Total slack | Free slack |
| --- | --- | --- | --- | --- | --- | --- | --- | --- | --- |
| 91 | 1.2.10 | **URBANISMO Y OBRAS DE ARTE** |  | 18d | 2021-05-10 | 2021-05-26 |  | 11d |  |
| 92 | 1.2.10.1 | Diseño de empradización y cerramiento segón diseño geométrico |  | 5d | 2021-05-10 | 2021-05-14 | 39FS-10d | 11d | 0d |
| 93 | 1.2.10.2 | Aprobación de empradización y cerramiento por Interventoría | milestone | 0d | 2021-05-16 | 2021-05-16 | 92FS+2d | 11d | 0d |
| 94 | 1.2.10.3 | Entrega de planos y especificaciones Urbanismo y Obras de Arte |  | 4d | 2021-05-21 | 2021-05-24 | 93FS+5d | 11d | 0d |
| 95 | 1.2.10.4 | Presupuesto Urbanismo y Obras de Arte |  | 2d | 2021-05-24 | 2021-05-26 | 94 | 11d |  |
| 96 | 1.2.11 | **AMBIENTAL Y SOCIAL** |  | 82d | 2021-03-09 | 2021-05-25 |  | 12d |  |
| 97 | 1.2.11.1 | Trazabilidad de requisitos legables aplicables al proyecto |  | 5d | 2021-03-09 | 2021-03-14 | 5SS+2d | 34d | 0d |
| 98 | 1.2.11.2 | PMA articulado con licencia Ambiental existente |  | 5d | 2021-03-14 | 2021-03-18 | 97 | 64d | 0d |
| 99 | 1.2.11.3 | Aclaración de dudas frente a la información |  | 5d | 2021-03-18 | 2021-03-23 | 98 | 64d | 52d |
| 100 | 1.2.11.4 | Revisiones especialista Ambiental Interventoría |  | 55d | 2021-03-09 | 2021-05-01 | 97SS | 34d | 22d |
| 101 | 1.2.11.5 | Ajuste fichas del PMA |  | 12d | 2021-05-12 | 2021-05-22 | 29FS-15d, 39FS-15d, 99, 65FS-15d | 12d | 0d |
| 102 | 1.2.11.6 | Entrega del PMA actualizado a Interventoría |  | 5d | 2021-05-21 | 2021-05-25 | 100, 101FS-2d | 12d | 0d |
| 103 | 1.2.11.7 | Aprobación actualización PMA por Interventoría | milestone | 0d | 2021-05-25 | 2021-05-25 | 102 | 12d |  |
| 104 | 1.2.12 | **EVALUACIÓN DE REDES Y EDIFICACIONES EXISTENTES** |  | 65d | 2021-04-07 | 2021-06-04 | 5FS-10d | 1d |  |
| 105 | 1.2.12.1 | Elaboración Acta de Vecindad |  | 65d | 2021-04-07 | 2021-06-04 | 5 | 1d |  |
| 106 | 1.2.13 | ENTREGA DE DISEÑOS PARA CONSTRUCCIÓN Y PRESUPUESTO | milestone | 0d | 2021-06-05 | 2021-06-05 | 4, 96, 20, 43, 79FS+1d, 90FS+1d, 102, 104, 103, 66, 95, 8, 34, 48 | 0d |  |
