# TERMINACIÓN CALLE DE RODAJE LIMA

Schedule from MS Project, 2021-10-01 to 2022-12-20, status date 2021-06-06, 9 hours a day, costs in $.

## Calendars

- Estándar: Mon-Sat 06:00-12:00, 13:00-20:00; Sun 07:00-12:00, 13:00-15:00. Exceptions (off unless hours are given): 2021-12-24 (Navidad), 2021-12-25 (Festivo Navidad), 2021-12-31 (Fin de Año), 2022-01-01 (Año Nuevo), 2022-01-02 (Domingo 2 de enero), 2022-04-14 (Jueves Santo), 2022-04-15 (Viernes Santo), 2022-04-17 (Domingo de Resurrección).

## Resources

| Resource | Rate |
| --- | --- |
| Etapa de preconstrucción | 500000000 |
| Pasamuro Ø14” HD L=50 cm Ext Brida x Ext Brida | 454249186 |
| Material para muro MSE | 346713516 |
| Plan de contingencia extremo durante 45 dias. Obras de Desvió red 14" | 154045622 |
| Cortes y Empalmes Tuberia red Alcantarillado 14" | 12705688 |
| Válvula de tapón APCO HD Ø 18” BRIDADA | 10686197 |
| Apoyo elastomerico de 100x81.25x10 dureza 60 | 9853277 |
| Sistema de hidroflujo (Incluye accesorios) | 9618813 |
| Tanque Séptico 5000 lts | 8997863 |
| Tanque Séptico de 10.000 lt | 8370000 |
| Válvula de cheque Marca APCO, Modelo 100R, DN 10" | 8134828 |
| Apoyo elastomerico de 700x700x70 dureza 60 | 7797487 |
| Tee reducida Ø14" x Ø6" BxB HD, ANSI Clase 150 | 7710000 |
| Válvula de tapón APCO HD Ø 14” BRIDADA | 7567036 |
| Pasamuro Ø14” HD L=60 cm Ext Brida x Ext Brida | 7443508 |
| Válvula compuerta brida HD de 12" | 7273624 |
| Válvula purga 10" con accesorios | 6787500 |
| Niple Ø10” HD L=57cm Ext brida | 6585304 |
| Tanque Cilindrico horizontal de 10.000 lt para almacenamiento de agua potable | 5851017 |
| Válvula ventosa 10" con accesorios | 5792249 |
| Válvula compuerta 10" con accesorios | 5658000 |
| Señalización preventiva | 5658000 |
| Tapón HDPE 32" | 5550000 |
| VALVULA ALIVIO PRESION APCO, SERIE 3000, MODELO 3006 (DIAMETRO 6") | 4886424 |
| Tee reducida Ø10" x Ø6" BxB HD, ANSI Clase 150 | 4779589 |
| Tee recta HDPE 32" | 4256899 |
| Pasamuro Ø14” HD L=50 cm Ext Brida x Ext Brida | 4256899 |
| Válvula combinada de aire para alcantarillado Marca APCO, SCAV Serie 440 - 2" x 7/32" | 4185000 |
| Tee reducida Ø 18” x 8” HD Bridada | 4122974 |
| Niple Ø14” HD L=46cm Ext brida x Ext. Bridada | 4059833 |
| Unión de montaje autoportante Ø 18” | 3784592 |
| Tee partida Ø 18” x 8” HD Bridada | 3672370 |
| Baliza Bidireccional verde verde recta | 3189930 |
| TEE 400 mm PE-100 RDE17 PN10 TOPE | 3148157 |
| Tanque Cilindrico horizontal de 5.000 lt para almacenamiento de agua potable | 3141905 |
| Válvula de compuerta Marca APCO CRF DN 250 - PN 16 | 3100000 |
| Prueba de presión en tubería de 14" | 3000000 |
| CODO 400mm X 90° PE-100 RDE17 PN10 TOPE | 2837511 |
| Tanque Fibra 5000 lt | 2745643 |
| Tee reducida Ø 14” x 6” HD Bridada | 2629617 |
| Tee partida Ø 14” x 6” HD Bridada | 2583820 |
| Válvula de compuerta Marca APCO PEC DN 150 - PN 16 | 2532000 |
| Válvula de tapón APCO HD Ø 8” BRIDADA | 2473166 |
| Reducción HD 14” x 10” Bridada | 2399349 |
| Rejilla T-100x30 de 3/16 x 3" 3048x915 Portante en platina de 3/16x3" cada 30mm, amarres en platina de 1x3/4" cada 100m,m. | 2300154 |
| Tee reducida Ø 14” x 4” HD Bridada | 2211638 |
| TEE RED 400mm X 250mm PE-100 RDE17 PN10 | 2182704 |
| Codo 45° HD Ø14” Junta Rápida (acoplable a tubería PVC) | 2171115 |
| TEE RED 400mm X160mm PE-100 RDE17 PN10 T.E | 1944616 |
| TEE RED 400mm X200mm PE-100 RDE17 PN10 T.E | 1944616 |
| Unión Tipo Dresser R1-R1 Ø14" HD | 1868124 |
| CODO 315mm X 90° PE-100 RDE17 PN10 TOPE | 1818917 |
| Tubería HDPE diametro 60" - Junta roscada | 1780092 |
| Tee partida en acero inoxidable 12" x 4" | 1767549 |
| Tubería HDPE diametro 60" - Junta roscada 2017 | 1747018 |
| Válvula de tapón APCO HD Ø 6” bridada | 1736533 |
| Pasamuro Ø14” HD L=85 cm Ext Brida x Ext Brida | 1732500 |
| Unión de montaje autoportante Ø 14” | 1715715 |
| Niple 14” HD I=80cm Ext brida x ext bridada | 1687500 |
| Pasamuro Ø18” HD L=50 cm Ext Brida x Ext Brida | 1687500 |
| Unión de reparación Ø14" | 1672879 |
| Unión rápida (unión Z) Ø14" | 1672879 |
| Tee partida en acero inoxidable 10" x 4" | 1595989 |
| Unión HD Brida x acople universal Ø 14” | 1472350 |
| CODO 400mm X 45° PE-100 RDE17 PN10 T.E | 1442670 |
| Tee reducida Ø 10” x 4” HD Bridada | 1404443 |
| Tee reducida Ø 10” x 6” HD Bridada | 1404443 |
| Codo 12.5” HD Ø14” Junta Rápida | 1399647 |
| Válvula ventosa de 4" | 1386064 |
| Reducción HD 14” x 10” Bridada | 1376350 |
| Pasamuro Ø14” HD L=70 cm Ext Brida x Ext Brida | 1350000 |
| Unión HD Brida x acople universal Ø 18” | 1296340 |
| Tee reducida HDPE de 8"x10" | 1289481 |
| RED. 400X250 mm PE-100 RDE17 PN10 TOPE | 1275562 |
| TEE 250 mm PE-100 RDE11 PN16 TOPE | 1260816 |
| Tanque Fibra 3000 lt | 1248296 |
| Tee HDPE de 10" | 1240202 |
| Tee reducida HDPE 6"x10" | 1180234 |
| TEE RED 250 mm X 160mm PE-100 RDE11 PN16 TOPE | 1180060 |
| TEE RED. 250X200 mm PE-100 RDE11 PN16 TOPE | 1180060 |
| Rejilla T-100x30 de 3/16 x 3" 1220x1220 Portante en platina de 3/16x3" cada 30mm, amarres en platina de 1x3/4" cada 100m,m. | 1176555 |
| TEE RED. 250X110 mm PE-100 RDE11 PN16 TOPE | 1162997 |
| TEE RED. 250X90 mm PE-100 RDE11 PN16 TOPE | 1162997 |
| TEE RED 250mm X 110mm PE-100 RDE17 PN10 T.E | 1137491 |
| Tee reducida HDPE de 3"x10" | 1065614 |
| Niple Ø10” HD I=110cm Ext brida x ext bridada | 975000 |
| Valvula y flotador 3" | 973082 |
| PORTABRIDA 400mm PE-100 RDE17 PN10 | 969098 |
| Pasamuro Ø14” HD L=40 cm Ext Brida x Ext Brida | 963800 |
| CODO 250mm X 90° PE-100 RDE11 PN16 TOPE | 929197 |
| Tee reducida HDPE 4"x8" | 918202 |
| TEE 250 mm PE-100 RDE17 PN10 TOPE | 914280 |
| Codo HDPE de 90 de 10" | 914006 |
| Codo HDPE de 90 de 10" | 914005 |
| Codo HDPE Gran Radio de 45 de 10" | 914005 |
| DISCO CORTE CONCRETO 14` DIAMANTADO-SEGMENTADO | 907022 |
| Tubería HDPE 36" | 863159 |
| Unión de montaje autoportante Ø 10” Brida x Brida | 852839 |
| TEE RED. 200X110 mm PE-100 RDE11 PN16 TOPE | 808519 |
| TEE RED. 200X160 mm PE-100 RDE11 PN16 TOPE | 808519 |
| TEE RED. 200X90 mm PE-100 RDE11 PN16 TOPE | 808519 |
| POSTE MADERA INMUNIZADA DE 12 MT | 801114 |
| CODO 250mm X 90° PE-100 RDE17 PN10 TOPE | 777821 |
| Codo 45” HD Ø10” brida*brida | 771582 |
| Codo HDPE de gran radio de 8" | 765105 |
| Unión HD Brida x acople universal Ø 14” | 753933 |
| BRIDA METÁLICA DN 16" (400mm) ANSI CL 150 | 741127 |
| Pasamuro Ø10” HD L=50 cm Ext Brida x Ext Brida | 729225 |
| Válvula purga de 4" | 701725 |
| CODO 250mm X 45° PE-100 RDE11 PN16 TOPE | 699932 |
| Semicodos HDPE | 695234 |
| CODO 250mm X 45° PE-100 RDE17 PN10 TOPE | 695140 |
| CodoHDPE de 45 de 10" | 688489 |
| TEE RED. 250X200 mm PE-100 RDE17 PN10 TOPE | 671026 |
| Tee PVC 100mm(4") DR18 C900 CxC | 645315 |
| Tanque Cilindrico horizontal de 2.000 lt para almacenamiento de agua potable | 642605 |
| Tanque Fibra 2000 lt | 630368 |
| Cilindro en concreto de 1,20 | 604750 |
| PORTABRIDA 315mm PE-100 RDE17 PN10 | 600340 |
| TEE 200 mm PE-100 RDE11 PN16 TOPE | 597556 |
| TEE RED 250 mm X 160mm PE-100 RDE17 PN10 TOPE | 583499 |
| TEE 200 mm PE-100 RDE17 PN10 TOPE | 537483 |
| Válvula compuerta 3". (Incluye brida). | 530149 |
| RED. 315X160 mm PE-100 RDE17 PN10 TOPE | 517924 |
| Kit adaptador brida HD 100mm(4") RAC 4204 C9 | 511871 |
| TEE RED. 250X110 mm PE-100 RDE17 PN10 TOPE | 507417 |
| Reducción HD 10”x6” Bridada | 503921 |
| Niple Ø6” HD I=110cm Ext brida x ext bridada | 498750 |
| Tuberia HDPE 18" | 483035 |
| Tapa y aro para pozo de inspección D=1.20m | 480486 |
| TEE RED. 200X160 mm PE-100 RDE17 PN10 TOPE | 480155 |
| PORTABRIDA 250mm PE-100 RDE7.4PN25TOPE | 472839 |
| PORTABRIDA 250mm PE-100 RDE9PN25TOPE | 472839 |
| Aro y tapa de caja de pozo de inspección de 24" | 470841 |
| RED. 250X200mm PE-100 RDE11 PN16 TOPE | 467550 |
| TEE RED. 250X90 mm PE-100 RDE17 PN10 TOPE | 466524 |
| Transformador de Aislamiento 25W | 461378 |
| Codo PVC 100mm(4")x45° DR18 C900 CxC | 457690 |
| Tubería HDPE 30" | 456531 |
| Concreto de 4000 PSI | 455714 |
| Cilindro para pozo de inspección de concreto prefabricado de 1.2 m de diámetro. H = 1m | 448723 |
| Concreto Tremie 28Mpa | 446550 |
| Cono para pozo de inspección D=1.20m | 439065 |
| Bateria 31H 1150 de tornillo | 420395 |
| TUBERIA 250 mm PE-100 RDE 7,4 PN16 | 416551 |
| TEE RED. 160X110 mm PE-100 RDE11 PN16 TOPE | 415199 |
| TEE RED. 160X90 mm PE-100 RDE11 PN16 TOPE | 415199 |
| RED. 250X200mm PE-100 RDE17 PN10 TOPE | 414619 |
| POSTE MADERA INMUNIZADA DE 8 MT | 412338 |
| RED. 250X160mm PE-100 RDE11 PN16 TOPE | 409216 |
| PORTABRIDA 250mm PE-100 RDE11PN16 TOPE | 406971 |
| TEE RED. 200X90 mm PE-100 RDE17 PN10 TOPE | 404013 |
| TEE RED. 200X110 mm PE-100 RDE17 PN10 TOPE | 400129 |
| Concreto 3500 PSI | 397266 |
| Manómetro conexión vertical Ø3/4” | 394500 |
| Concreto de 210 kg/cm2 | 393596 |
| RED. 250X160mm PE-100 RDE17 PN10 TOPE | 391280 |
| Concreto 3000 psi | 390184 |
| CODO 200 mm X 90° PE-100 RDE11 PN16 TOPE | 389149 |
| Barrera naranja tipo maletín | 388755 |
| RED. 250X110mm PE-100 RDE17 PN10 TOPE | 379463 |
| RED. 250X90mm PE-100 RDE17 PN10 TOPE | 379463 |
| Mortero de pega 1:4 | 374853 |
| Reducción HDPE de 10" a 6" | 373694 |
| Tubería HDPE 16" | 367937 |
| Flotador para tanque de almacenamiento Ø 2". Incluye válvula | 366285 |
| PORTABRIDA 250mm PE-100 RDE17 PN10 TOPE | 356159 |
| Pasamuro Ø6” HD L=50 cm Ext Brida x Ext Brida | 348750 |
| Concreto 2500 psi | 345592 |
| Concreto 2500psi | 345592 |
| PTS: Perfil metalico (10x10) x 6mts x 2mm de espesor | 334444 |
| Tubo PVC 200mm(8") DR18 C900 CxE CE | 308294 |
| Tubería HD 250mm DN | 304238 |
| Juego de tornillería – Empaque BR 14 CL 125 DELTA | 302500 |
| Flotador de 2" para tanque de agua | 301381 |
| Juego de tornillería – Empaque BR 14 CL 125 DELTA | 300000 |
| Maletin plástico de señalización (2x1x0.5) | 299900 |
| TUBERIA 250 mm PE-100 RDE 09 PN16 | 299877 |
| Yee HDPE 6" | 299645 |
| Codo 22.5” HD Ø6” brida*brida | 296189 |
| Codo 90” HD Ø6” brida*brida | 291218 |
| CODO 200 mm X45° PE-100 RDE11 PN16 TOPE | 291083 |
| LAMPARA SODIO DE 150WAT CERRADA | 289579 |
| Tee HDPE 6" | 283782 |
| Niple Ø6” HD I=40cm Ext brida x ext bridada | 277500 |
| TEE 160 mm PE-100 RDE11 PN16 TOPE | 276363 |
| PTS de 4mm X 100 X 100 x 6000 mm | 269757 |
| Unión HD Brida x acople universal Ø 10” | 266781 |
| Juego de tornillería – Empaque BR 18 CL 125 DELTA | 264246 |
| CODO 200 mm X 90° PE-100 RDE17 PN10 TOPE | 261916 |
| CODO 200 mm X45° PE-100 RDE17 PN10 TOPE | 261916 |
| Tee PVCS Ǿ 8" | 260825 |
| Codo HDPE de 45 de 6" | 257633 |
| Codo HDPE de 45 de 8" | 257633 |
| Codo HDPE de 90 de 8" | 257633 |
| BRIDA METÁLICA DN 12" (315mm) ANSI CL 150 | 252606 |
| Malla electrosoldada 6*6-W1.4*W1.4 (6m x 2,35m) | 248743 |
| Malla electrosoldada 6*6-W2.9*W2.9 (6m x 2,35m) | 248743 |
| TEE 160 mm PE-100 RDE17 PN10 TOPE | 248731 |
| tubería Novafort 24" | 247786 |
| Tuberia HDPE 12" | 243009 |
| Malla de alambre eslabonado vehicular | 239685 |
| Defensa metálica en Viga W calibre 12 y poste W6 cada 1,9m. H de la defensa = 0,7m | 238570 |
| TUBERIA 250 mm PE-100 RDE 11 PN16 | 230850 |
| Codo HDPE de gran radio de 6" | 230631 |
| Tee unión rápida HDPE 3" | 225344 |
| Codo 90” HD Ø6” Junta Rápida | 216274 |
| CODO 160 mm X 90° PE-100 RDE11 PN16 TOPE | 213479 |
| Yee PVCS Ǿ 8" | 202923 |
| TEE RED. 160X90 mm PE-100 RDE17 PN10 TOPE | 199931 |
| TEE RED. 160X110 mm PE-100 RDE17 PN10 TOPE | 195572 |
| Juego de tornillería – Empaque BR 10 CL 125 DELTA | 188500 |
| Anillo de concreto de 24" de diámetro para pozo de inspección | 187289 |
| EPOXICO PARA ANCLEJE EN CONCRETO | 180000 |
| Kit de derrames | 178267 |
| RED. 200X160 mm PE-100 RDE17 PN10 TOPE | 176182 |
| RED. 200X110 mm PE-100 RDE11 PN16 TOPE | 176175 |
| RED. 250X110mm PE-100 RDE11 PN16 TOPE | 176175 |
| RED. 250X90mm PE-100 RDE11 PN16 TOPE | 176175 |
| Reducción HDPE de 8" a 4" | 174018 |
| Adaptador macho HDPE 110mm X 4" | 171869 |
| RED. 200X110 mm PE-100 RDE17 PN10 TOPE | 171044 |
| RED. 200X90 mm PE-100 RDE17 PN10 TOPE | 171044 |
| CODO 160 mm X45° PE-100 RDE11 PN16 TOPE | 169203 |
| Flotador para tanque de almacenamiento Ø 1". Incluye válvula | 164410 |
| Tubería HDPE 10" | 158169 |
| Valvula CS Ǿ3" tipo mariposa | 156903 |
| REFLECTOR LED DE 70 | 153154 |
| CODO 160 mm X 90° PE-100 RDE17 PN10 TOPE | 152510 |
| CODO 160 mm X45° PE-100 RDE17 PN10 TOPE | 152510 |
| Codo HDPE de 90 de 6" | 150017 |
| Codo HDPE de gran radio de 4" | 150016 |
| BRIDA METÁLICA DN 10" (250mm) ANSI CL 150 | 148734 |
| RED. 200X160 mm PE-100 RDE11 PN16 TOPE | 148041 |
| RED. 200X90 mm PE-100 RDE11 PN16 TOPE | 148041 |
| Unión rápida HDPE 4" | 146193 |
| Malla de gavión 2m x 1 m | 145929 |
| Poste DV C6,0mm Galv | 140063 |
| TUBERIA 200 mm PE-100 RDE 11 PN16 | 138334 |
| Tee HDPE 4" | 138217 |
| PORTABRIDA 200mm PE-100 RDE11 PN16 TOPE | 134109 |
| PORTABRIDA 200mm PE-100 RDE17 PN10 TOPE | 131980 |
| TAPA VALVULA TIPO CHOROTE | 131825 |
| Juego de tornillería – Empaque BR 10 CL 125 DELTA | 131616 |
| BREAKER IND. DE 40 AMP | 129592 |
| Tee PVC presión 4" | 129115 |
| Unión HD Brida x acople universal Ø 6” | 128147 |
| Flotador de 1" para tanque de agua | 120997 |
| Valvula bola PVC presión 4" | 119174 |
| RED. 160X110 mm PE-100 RDE11 PN16 TOPE | 110776 |
| RED. 160X90 mm PE-100 RDE11 PN16 TOPE | 110776 |
| Codo PVCS 8" x 90 | 109341 |
| Abrazadera de acero galvanizado 4" x 3/8" con perforación para anclaje a pernos embebidos | 108806 |
| RED. 160X110 mm PE-100 RDE17 PN10 TOPE | 107880 |
| RED. 160X90 mm PE-100 RDE17 PN10 TOPE | 107549 |
| Unión universal 3" presión | 106706 |
| Reducción HDPE de 6" a 4" | 106126 |
| Valvula de paso metálica presión 2" | 105488 |
| valvula paso galvanizada presión de 2" | 104672 |
| BRIDA METÁLICA DN 8" (200mm) ANSI CL 150 | 101705 |
| PLACA PLANA R51 200X200X35-060MM | 101631 |
| Pasamuro Ø3” HD L=50 cm Ext liso Ext liso | 101250 |
| Angulo Galv 100x100x6x400 | 99892 |
| Codo 90° PVC presión 4" | 99231 |
| Codo PVCS 8" x 45 | 98222 |
| Juego de tornillería – Empaque BR 6 CL 125 G2 DELTA | 98200 |
| Tee PVCS Ǿ 6" | 97435 |
| Tubería HDPE 8" | 92519 |
| Pintura amarilla reflectivo | 91281 |
| Manguera reforzada transparente Ø 3". | 91036 |
| Válvula de bola PVC 4" | 91036 |
| PORTABRIDA 160mm PE-100 RDE17 PN10 TOPE | 90115 |
| Unión rápida HDPE 3" | 89708 |
| TUBERIA 160 mm PE-100 RDE 11 PN16 | 88450 |
| TEE 110 mm PE-100 RDE17 PN10 TOPE | 88393 |
| Barra R51-800 L=3 m | 86783 |
| Bolso kit de derrames | 84921 |
| Unión rápida HDPE 2" | 83539 |
| Tubo PVC 100mm(4") DR18 C900 CxE CE | 83523 |
| Pasamuro Ø3” HD L=40 cm Ext liso Ext liso | 82500 |
| TEE RED. 110X90 mm PE-100 RDE17 PN10 TOPE | 81695 |
| CODO 110 mm X45° PE-100 RDE17 PN10 TOPE | 81581 |
| CODO 110 mm X 90° PE-100 RDE17 PN10 TOPE | 81568 |
| Garita en madera y techo de zinc (2m x 1m) | 81288 |
| Juego de tornillería – Empaque BR 4 CL 125 G2 DELTA | 81121 |
| BROCA DE BOTONES R51-100 ENDURECIDA | 81000 |
| Malla galvanizada de 51mm cal 10.5 | 80824 |
| Codo HDPE de 45 de 4" | 80248 |
| Codo HDPE de 90 de 4" | 80234 |
| Empaque neopreno para brida de 16" | 78684 |
| Yee PVCS Ǿ 6" | 78031 |
| Malla de gavión 1x1x1 (canasta) | 76944 |
| TUERCA R51 TIPO "A" | 75510 |
| Empaque BR 14 CL 125 DELTA | 75150 |
| Barra autoperforante R32. Incluye (Broca, placa, tuerca y centrador) | 74971 |
| Material granular filtrante Ǿ1" a 1-1/2" | 74770 |
| Valvula bola PVC presión 3" | 72693 |
| Pintura tipo esmalte | 72463 |
| Aglomerante estabilizador | 71490 |
| ACOPLE R51 TIPO "A" (Mango de union) | 70970 |
| BRIDA METÁLICA DN 6" (160mm) ANSI CL 150 | 70480 |
| Terminal DV de 0,71m Galv | 70102 |
| Codo PVCS 6" x 90 | 68570 |
| Tubería PVC presión 4" | 67729 |
| Juego de tornillería – Empaque BR 6 CL 125 G2 DELTA | 66852 |
| PORTABRIDA 160mm PE-100 RDE11 PN16 TOPE | 65291 |
| Tablero 8 circuitos monofásico 220 Voltios AC | 63571 |
| Ductos eléctricos subterráneos | 63011 |
| Tubería acero galvanizado 3" x 2 metros | 62004 |
| Grava para preparación de concretos. Incluye fractura de roca. | 61746 |
| Varilla Galv Roscada 3/4" | 60985 |
| Empaque neopreno para brida de 12" | 59105 |
| Tubería HDPE 6" | 59095 |
| Valvula bola PVC presión 2" | 58982 |
| Aspersor para riego de 13 a 18 m de rango | 58798 |
| Caja de servicios multiples | 57239 |
| Soldadura PVC x 1/4 Gal | 56656 |
| TEE 90mm PE-100 RDE17 PN10 TOPE | 54485 |
| Adaptador Hembra PVC presión 4" | 54399 |
| Empaque BR 10 CL 125 DELTA | 53200 |
| Base (Santafe) | 52396 |
| Unión PVCS Ǿ8" | 51140 |
| Aviso Imantado (50*30 LAMINADO CON LOGO) | 50980 |
| TRITURADO DE 3/8` X M3 | 49409 |
| BRIDA METÁLICA DN 4" (110mm) ANSI CL 150 | 48686 |
| Union PVC C900 DR18 | 48195 |
| Unión PVC presión 4" | 48070 |
| Sub-Base (Santa fe) | 47937 |
| Empaque BR 6 CL 125 G2 DELTA | 47500 |
| RED. 110X90 mm PE-100 RDE17 PN10 TOPE | 46608 |
| Codo HDPE de 45 de 3" | 45848 |
| Reducción HDPE de 4" a 3" | 45848 |
| Codo 90° PVC presión 3" | 45741 |
| Juego de tornillería – Empaque BR 4 CL 125 G2 DELTA | 45642 |
| Colombinas plásticas de señalización | 45000 |
| Terminal de defensa metálica | 44943 |
| Adaptador Macho PVC presión 4" | 44328 |
| Material para cama de tubería (tamaño máximo nominal hasta de 3/4"). | 44227 |
| Geomembrana HDPE texturizado de 80 mil | 43050 |
| Abrazadera Ø 14” | 43000 |
| CODO 90 mm X 90° PE-100 RDE17 PN10 TOPE | 42600 |
| CODO 90 mm X45° PE-100 RDE17 PN10 TOPE | 42600 |
| Piedra Rajon 30-50 | 41940 |
| Codo HDPE de 90 de 3" | 41905 |
| Codo HDPE de gran radio de 3" | 41904 |
| Arena importada (cantera Santafe) | 40691 |
| BRIDA METALICA DN 3" (90mm) ANSI CL 150 | 40019 |
| Tubería PVC presión 3" | 39708 |
| Triturado 3/4" Arenas y triturados Santa fe | 39527 |
| Afirmado | 39018 |
| Barra de acero con tensor | 39018 |
| Válvula PVC presión Ø 2" | 38235 |
| Tubo galvanizado de 4" | 37485 |
| Tubería acero galvanizado 2,5" x 2 metros | 37302 |
| Grava compactada (25mm) | 36979 |
| Semilla certificada de pasto | 36950 |
| Rechazo para producción de grava y arena sin lavar (20% del material crudo a procesar). | 36852 |
| Tubería PVCS Ǿ8" | 36073 |
| PORTABRIDA 110mm PE-100 RDE17 PN10 TOPE | 35304 |
| Limpiador PVC x 1/4 Gal | 35236 |
| Tee PVC presión Ø 3" | 34272 |
| RED. 90X32 mm PE-100 RDE17 PN10 TOPE | 33609 |
| RED. 90X50mm PE-100 RDE17 PN10 TOPE | 33609 |
| Triturado importado 3/4" | 33444 |
| Codo PVCS 6" x 45 | 33143 |
| Buje PVC presión 4" x 2" | 33111 |
| Buje PVC presión 4" x 3" | 33111 |
| Empaque BR 4 CL 125 G2 DELTA | 32240 |
| base granular (Sub base) - Tipo ABC | 32027 |
| Geomembrana MACLINE GCL W 40 5.0 | 31396 |
| Tubería acero galvanizado 1,9" x 2 metros. Incluye doblez | 31002 |
| Kit de sellado | 30941 |
| Pala plastica antichispa | 30881 |
| CINTA SCOTH SUPER 33 AUTOFUNDENTE | 30395 |
| Adaptador Hembra PVC presión 3" | 30125 |
| Manómetro conexión vertical Ø3/4” | 30118 |
| Tubo metálico acero al carbón 3" pintado. L = 0,8m | 30103 |
| Separador DV C3/16" 0,36mm | 29874 |
| Geomembrana HDPE lisa de 60 mil | 29352 |
| Rechazo para producción de grava compactada (base) (18% del material crudo a procesar). | 28720 |
| Grava compactada (50mm) | 28093 |
| Pernos+Tuerca+arandela | 27870 |
| Rechazo para producción de base granular (sub-base) - Tipo ABC (15% del material crudo a procesar) | 27849 |
| Tubería HDPE 4" | 27831 |
| Tee HDPE 3" | 27709 |
| PORTABRIDA 90mm PE-100 RDE17 PN10 TOPE | 27644 |
| Peldaños varilla de 5/8" | 27337 |
| PORTABRIDA 90mm PE-100 RDE17 PN10 TOPE | 27162 |
| Tubo PVC sanitario 150mm | 27146 |
| ESPACIADOR R51-095 (centrador) | 26915 |
| Geomembrana MACLINE GCL W40 3.6 | 26415 |
| Pasamanos en acero galvanizado | 25083 |
| Copa galvanizada de 3" x 2" | 24860 |
| Listón madera L=3m | 24526 |
| Adaptador Macho PVC presión 3" | 24099 |
| Tubería perforada para filtros Ǿ6" | 23311 |
| Tipo B400 (Metatron Bogotá) | 22650 |
| Rechazo para producción de grava compactada (Sub-base) (14% del material crudo a procesar). | 21796 |
| Tapón PVCS Ø 6" | 21666 |
| VARILLA DE ANCLAJE 5/8 X 1.80 | 20617 |
| Unión PVCS Ǿ6" | 20502 |
| teja de zinc L=2,80m | 20242 |
| Cable encauchetado 4X6 | 20240 |
| Unión universal 2" presión | 19255 |
| Tubería HDPE 3" | 19090 |
| larguero 10x10x300 cm | 18555 |
| Geotextil NT 12 oz/yd2 (NT7000) | 18411 |
| Breaker 2x30 30 A | 18355 |
| Concertina calibre 10" | 17837 |
| CINTA AISLANTE 3M | 17672 |
| Empaque neopreno para brida de 10" | 17256 |
| Tubo PVC presión de 3" | 16500 |
| Yee PVCS Ǿ 4" | 16341 |
| Codo PVC 90° presión 2" | 16311 |
| Tapón PVCS Ø 4" | 15294 |
| Material pasa 75mm para rellenos estructurales | 14820 |
| collar de derivación de 3" x 1/2" | 14392 |
| BLOQUE DE RETENIDA | 14137 |
| Rechazo (10% del material crudo a procesar) | 13901 |
| Rechazo para producción de material pasa 75mm roca estructural (10% del material crudo a procesar) | 13901 |
| Material pasa 100mm para MSE Walls y rellenos estructurales | 13801 |
| Tuberia HDPE 2" | 13478 |
| poste en madera para cerca | 13388 |
| Reducción PVC presión 3"x2" roscado. | 13388 |
| Tapón PVC presión Ø 3" | 13382 |
| Tee PVC presión de 2" | 13066 |
| Rechazo para producción de material pasa 100mm paa MSE (10% del material crudo a procesar) | 12774 |
| Insumos de tensionamiento (cuñas, bloques, trompetas, ductos, toron) | 12500 |
| Cespedón tipo estrella (Incluye capa de tierra negra) puesto en sitio | 12317 |
| Empaque neopreno para brida de 8" | 12229 |
| Tubería PVCS Ǿ4" | 12160 |
| Tornillos y accesorios para defensa metalica | 11995 |
| Cercha Metálica | 11941 |
| Union PVC hembra de 3" | 11776 |
| Adaptador macho galvanizado de 3" | 11339 |
| Aditivo acelerante de fraguado para concreto | 10791 |
| Tuberiá de presión PVC de 2" | 10758 |
| Tee PVCS Ǿ 4" | 10632 |
| Captafaro | 10613 |
| Geotextil NT 8 oz/yd2 (NT4000) | 10387 |
| Abrazadera métalica Ø 3" | 10196 |
| PERCHA COMPLETA DE 2-1/2 | 10014 |
| Geotextil NT 6000 10oz | 9911 |
| Estructura metálica liviana | 9909 |
| Cable o guaya alma de acero de 1/2" | 9327 |
| Agromanto | 9259 |
| Codo PVCS 4" x 45 | 9031 |
| Cinta de Vinilo | 9000 |
| Tuberiá de presión PVC de1 1/2" | 8889 |
| CABLE ENCAUCHETADO 3X10 | 8836 |
| Madera rolliza h=3m | 8774 |
| A.C.P.M. | 8426 |
| Desmoldante | 8426 |
| Curador para concreto | 8361 |
| Empaque neopreno para brida de 6" | 8085 |
| Codo PVCS 4" x 90 | 8028 |
| Buje 3*2 PVC Presión soldado | 8025 |
| larguero 2"x4"x300 cm | 7900 |
| Codo PVC presión de 2" x 45 | 7884 |
| Fertilizante 15 - 15 - 15 | 7818 |
| Geomalla Biaxial LBO302 o SIMILAR | 7689 |
| Codo PVC presión de 1,1/2"x 45 | 7497 |
| Geomembrana 20 mils | 7497 |
| Tee PVCS Ǿ 1,1/2" | 7497 |
| Fibra metálica | 7469 |
| Tee PVC presión Ø 2" | 7283 |
| Niple galvanizado 2" | 7240 |
| Esparrago de 1" x 6" ASTM A193 grado B7 galvanizado | 7221 |
| Breaker 1x20 30 A | 7143 |
| Cadena plástica de señalización | 7023 |
| Codo PVC presión de 2" x 90 | 6962 |
| Disipadores de energía | 6962 |
| Perro o prensacable pesado 5/8" | 6948 |
| Alambre galvanizado | 6898 |
| Estopa | 6804 |
| Fibra sintética | 6555 |
| Manguera transparente Ø 1" | 6423 |
| Tapón PVC presión Ø 2" | 6372 |
| Manguera PE 3" | 6363 |
| Captafaro plastico BI-DIREC | 6105 |
| Codo PVC presión de 1,1/2" x 90 | 6105 |
| Adaptador hembra PVC presión Ø 2" | 5998 |
| Cable o guaya alma de acero de 3/8" | 5617 |
| Codo PVC Sanitario 90” Ø3” | 5604 |
| Empaque neopreno para brida de 4" | 5416 |
| Agua para riego | 5355 |
| Mulch con componente organico | 5248 |
| Union tuberia PE 3" | 5034 |
| Cadena plastica de señalización (100m) | 4949 |
| Tubería PVC 1-1/2" | 4766 |
| Unión PVCS Ǿ4" | 4677 |
| Esparrago de 7/8" x 51/2" ASTM A193 grado B7 galvanizado | 4611 |
| Perro o prensacable pesado 1/2" | 4563 |
| Adaptador macho PVC presión Ø 2" | 4552 |
| Unión PVC presión 2" | 4515 |
| Grapas | 4498 |
| Tuberiá de presión PVC de 1" | 4445 |
| Unión PVC presión de 1,1/2" | 4284 |
| Unión PVC presión de 2" | 4284 |
| TRENZA NUMERO 6 XLP 90GRADOS | 4194 |
| Adaptador hembra PVC presión de 2" | 4187 |
| Alambre recocido | 4049 |
| valvula paso de 1/2" | 3925 |
| Empaque neopreno para brida de 3" | 3755 |
| Tubo conduit PVC 1" | 3752 |
| Alambre recocido | 3582 |
| Geotextil NT 1600 | 3550 |
| ARANDELAS DE 5/8 4X4 | 3534 |
| PRENZA-ESTOPA DE 1 | 3534 |
| Icopor 1/2" | 3392 |
| Formaleta Tipo 2: Encofrado mas complejo que para la Formaleta tipo 1 (Estructuras) | 3344 |
| Esparrago de 3/4" x 4 3/4" ASTM A193 grado B7 galvanizado | 3020 |
| Tuberiá de presión PVC de 3/4" | 3017 |
| CABLE ENCAUCHETADO 3X16 | 2945 |
| Tee PVC presión 1" | 2905 |
| Acero de refuerzo 60.000 p.s.i. | 2853 |
| Ángulo 1 + 1/8" | 2810 |
| Aditivo expansor para concreto | 2678 |
| Buje PVC presión 1" x 3/4" | 2622 |
| Adaptador macho PVC presión de 2" | 2617 |
| Niple galvanizado 3/4" x 10 | 2617 |
| Adobe (ladrillo en concreto) de 20 cm x 40 cm | 2564 |
| Tuberiá de presión PVC de 1/2" | 2480 |
| Malla PVC naranja - h=1.0m | 2476 |
| Lona verde | 2358 |
| Aditivo plastificante para concreto | 2356 |
| CONECTOR COMPRESION AP1 | 2333 |
| Formaleta Tipo 1: Encofrado sencillo sin quiebres (placas) | 2230 |
| Tuerca esparrago 1" ASTM a 194 2 h | 2226 |
| Bentonita-cemento | 2214 |
| Bentonita-Suelo | 2214 |
| Codo 90° PVC presión 1" | 2088 |
| Clavos x 2" y 3" | 2061 |
| Consumibles | 1850 |
| Esparrago de 5/8" x 4" ASTM A193 grado B7 galvanizado | 1812 |
| CABLE SUPER GX DE 1/4 | 1767 |
| Adaptador Hembra PVC presión 1" | 1751 |
| Tuerca esparrago 7/8" ASTM a 194 2 h | 1558 |
| Guardacabos de 5/8 | 1414 |
| Polisombra verde 2 m | 1339 |
| Accesorios tubería PVC presión de 1" | 1285 |
| Adaptador macho PVC presión Ø 1" | 1274 |
| Tuerca esparrago 3/4" ASTM a 194 2 h | 959 |
| Cal hidratada | 934 |
| Caja PVC 10x10 | 891 |
| Lechada para ductos | 840 |
| Arandela Plana 3/4" | 825 |
| Alambre de Púas | 734 |
| Teflon | 698 |
| Unión PVC presión 3/4" | 673 |
| Tuerca esparrago 5/8" ASTM a 194 2 h | 624 |
| Accesorios tubería PVC presión de 3/4" | 589 |
| Cemento en saco | 536 |
| Costales de fibra | 536 |
| Curva PVC 1" 45 mm | 482 |
| Tuerca Galv | 471 |
| Accesorios tubería PVC presión de 1/2" | 428 |
| Unión PVC presión 1/2" | 427 |
| Cinta de señalización amarilla | 426 |
| Cinta de señalización azul | 424 |
| Cinta de señalización blanca | 424 |
| Cinta de señalización roja | 424 |
| Cinta de señalización verde | 424 |
| Cal agricola | 412 |
| Adaptador PVC 1" | 307 |
| Tapa lisa 4x4 PVC | 240 |
| Cinta No 33 | 74 |
| Agua | 59 |
| Bombeo de aguas en 4” |  |
| Bombeo de aguas en 6” |  |
| tubería biaxial PVC 14" TIPO RDE 37 |  |
| SACOS PROLIPROPILENO DE 0.92M X 0.60 M PARA CONTENCIÒN Y APOYO TUBERIAS |  |
| ENTIBADO METALICO TIPO KRINGS |  |
| SOPORTE TUBERÍA RED CONTRAINCENDIOS |  |
| TUBERÌA BIAXIAL PVC 14" TIPO RDE 37 |  |
| TUBOS Ф 6" PVC , TIPO TDP PARA DUCTOS Ф 6" |  |
| DUCTOS 4X6" PVC, TIPO TDP AREAS CON PAVIMENTO (NO INCLUYE SUMINISTRO TUBOS PVC Ф 6") |  |
| DUCTOS 4x6" PVC, TIPO TDP AREAS NO PAVIMENTO (No incluye suministro tubos PVC Ф 6") |  |
| tuberìa pvc 4" para drenaje de cajas electricas existentes (no incluye excavaciòn, rellenos y disposiciòn de material) |  |
| EMPALME MT PARA CABLE 4/0 Cu, 15KV, XLPE |  |
| TUBERIA BIAXIAL PVC 6" RDE 37 |  |
| Tubería PVC Biaxial 6" RDE 37 |  |
| CAJA PARA VALVULA TIPO CHOROTE TRAFICO PESADO |  |
| TAPA VALVULA TIPO CHOROTE TRAFICO PESADO |  |
| tubería de 10" |  |
| Unión rápida (unión Z) Ø10" |  |
| TUBERÌA BIAXIAL PVC 10" TIPO RDE 21 |  |
| SOPORTE TUBERÍA RED CONTRAINCENDIOS |  |
| TUBERÌA BIAXIAL PVC 10" TIPO RDE 21 |  |
| Excavadora de orugas tipo 320 |  |
| Excavadora de orugas con martillo |  |
| Compresor Neumático |  |
| Martillo neumático demoledor con manguera y punta |  |
| Bulldozer tipo D6 |  |
| Vibrocompactador tipo 250 |  |
| Vibro manual para concreto |  |
| Carrotanque capacidad 10.000 litros |  |
| Volqueta dobletroque |  |
| Motoniveladora |  |
| Cargador Volvo 1,8 m3 |  |
| Canguro |  |
| Bomba de concreto (estacionaria) |  |
| Maquinaria termo fundente para tubería hasta 18" |  |
| Minicargador |  |
| Trituradora primaria |  |
| Criba |  |
| Cono |  |
| Volqueta Dumper 30 tn |  |
| Pistola para Junta interna tubería HDPE |  |
| Carrotaller |  |
| Planta eléctrica 5.5 Kva |  |
| Concretadora Saco |  |
| Herramienta menor 5% |  |
| Herramienta menor 10% |  |
| Guadaña |  |
| Herramienta menor para control de trafico (señalización) |  |
| Cargador Doosan 2,5 m3 |  |
| Equipo de soldadura (inversor) |  |
| Equipo de soldadura (moto-soldador) |  |
| Carrotanque capacidad 5.000 litros |  |
| Computador |  |
| Modem de internet |  |
| Carro tanque 5000 lt |  |
| Equipo de Bombeo conducción y aspersión |  |
| Hidrosembradora |  |
| Camioneta 4x4 |  |
| Autohormigonera |  |
| Retrocargador |  |
| Equipo de perforación |  |
| Equipo para inyección de lechada |  |
| Equipo de trituración (impactor + criba) |  |
| Luminaria con planta eléctrica |  |
| TORQUIMETRO CUADRANTE 3/4 DE 90 A 600 LB CERTIFICADO |  |
| Cortadora de adobe |  |
| Andamios certificado |  |
| Planta eléctrica 25 Kva |  |
| Equipo pruebas hidrostaticas |  |
| Piloteadora |  |
| Electrobomba sumergible |  |
| Equipo de Oxicorte |  |
| Rotomartillo SDS PLUS |  |
| Bomba hidraulica de tensionamiento PE554 |  |
| Gato hidraulico 250TON |  |
| Equipo de topografía |  |
| Extrusora de polietileno de alta densidad |  |
| Camión |  |
| Hidrolavadora a gasolina |  |
| Motobomba de 3" autocebante a gasolina |  |
| Motobomba de 6" motor 64 HP autocebante |  |
| Ayudante 1 |  |
| Ayudante Entendido |  |
| Oficial 1a |  |
| Oficial 2a |  |
| Encargado 1 |  |
| Ayudante 2 |  |
| Ayudante Entendido |  |
| Oficial 3a |  |
| Oficial 4a |  |
| Encargado 2 |  |
| Ingeniero para software de calidad |  |
| Cuadrilla Electrica |  |
| Oficial Electrico |  |
| Ingeniero Electrico |  |
| Topografo |  |
| Cadenero primero |  |
| Cargue, transporte de escombros |  |
| Transporte en volqueta doble troque |  |
| Transporte en camion |  |
| Transporte interno tubería 30" |  |
| Transporte interno tubería 36" |  |
| Transporte Tubería acampanada 30 desde Medellín |  |
| Transporte Tubería acampanada 36" desde Medellín |  |
| Transporte anillo prefabricado |  |
| Transporte aro y tapa |  |
| Transporte cuenca de captación |  |
| Bombeo de concreto |  |
| Transporte para acero |  |
| Transporte roca |  |
| Transporte tuberia 60" Medellín- Higabra |  |
| Transporte tubería 3" Medellín - Higabra |  |
| Transporte en dobletroque Bgota -el dorado |  |
| Acarreo interno tubería Cauca |  |
| Acarreo interno Combustible Cauca |  |
| Acarreo interno 2 Km hacia zaranda clasificadora |  |
| Transporte tracción animal y/o equipo para área tubería Río Cauca |  |
| Alimentación personal local |  |
| Transporte de equipos especiales (primaria, criba y cono) |  |
| alquiler baño portátil (2 aseos en la semana) |  |
| Construcción de gaviones |  |
| Derechos de escombrera / m3 |  |
| Prueba Pozo Higabra |  |
| Alimentación y hospedaje personal foráneo |  |
| Mantenimiento Pozo Séptico 10 m3 |  |
| Mantenimiento Pozo Séptico 6m3 |  |
| Subcontrato movimiento planta eléctrica PELG-22 |  |
| Prueba de carga |  |
| Movilización para equipos adicionales de trituración. Trituradora |  |
| Movilización para equipos adicionales de trituración. Criba |  |
| Desmovilización para equipos adicionales de trituración. Trituradora |  |
| Desmovilización para equipos adicionales de trituración. Criba |  |
| Transporte camabaja 4 ejes Cativo a Filadelfia |  |
| Escolta cabaja 4 ejes Cativo a Filadelfia |  |
| Operación y manternimiento de grúa Grove 130Ton |  |
| Transporte Luminaria |  |
| Servicio de examen de mercurio en sangre |  |
| Rx de torax PA y lateral |  |
| Determinacion de marihuana y cocaina |  |
| Vacuna de tetano |  |
| Transportes examenes médicos |  |
| Operador, aparejadores y supervisor de izajes para operación de grua 130 T |  |
| Combustible para operación de grua 130 T |  |
| Mantenimiento rutinario (2 visitas por mes) |  |
| Mantenimiento rutinario para 1000, 1250, 1500, 1750, 2000, 2250, 2500 y 2750 |  |
| Eslingas y grilletes |  |
| Servicio e instalación de modulos Grua Grove 130 T |  |
| Servicio de transporte de grua desde Buriticá hasta santafe de antiquia |  |
| Servicio de escolta para carga extradimensionada |  |
| Acarreo interno de concreto |  |
| Acarreo interno para apoyo elastomerico |  |
| Acarreo interno de torón |  |
| Acarreo interno-varios |  |
| Viaje tuberia |  |
| Acarreo de material 1 |  |
| Acarreo de material 2 |  |
| Acarreo de material 3 |  |
| Transporte 1 |  |
| Transporte 2 |  |
| Transporte 3 |  |

## Schedule

| ID | WBS | Task | Type | Duration | Start | Finish | Predecessors | Baseline start | Baseline finish | Baseline duration | Total slack | Free slack | Constraint | Resources | Cost | Baseline cost | Text3 | Un |
| --- | --- | --- | --- | --- | --- | --- | --- | --- | --- | --- | --- | --- | --- | --- | --- | --- | --- | --- |
| 1 | 0.1 | Orden Inicio | milestone | 0d | 2021-10-01 | 2021-10-01 |  | 2021-08-02 | 2021-08-02 | 0d | 0d |  | start no earlier than 2021-10-01 |  |  |  | OI |  |
| 2 | 0.2 | **ETAPA DE CONSTRUCCIÓN** |  | 591d | 2021-10-01 | 2022-12-20 |  | 2021-08-02 | 2022-08-10 | 494d | 0d |  |  |  | 262,069,428,822 | 330,134,023,113 | EC |  |
| 3 | 1 | **PRELIMINARES** |  | 354d | 2021-10-01 | 2022-06-28 |  | 2021-08-02 | 2022-04-25 | 350d | 5d |  |  |  | 892,886,430 | 841,097,294 |  |  |
| 4 | 1.1 | Localizacion, replanteo y control topografico de las obras |  | 354d | 2021-10-01 | 2022-06-28 | 1SS | 2021-08-02 | 2022-04-25 | 350d | 5d | 0d |  | Etapa de preconstrucción [32872%] | 417,498,557 | 376,611,746 | 1.1 | m2 |
| 5 | 1.2 | Cerramiento provisional h=2,00 m. en repisa y lona verde |  | 65d | 2021-10-05 | 2021-11-22 | 4SS+6d | 2021-08-02 | 2021-08-27 | 35d | 5d | 0d |  | Etapa de preconstrucción [1819%] | 29,089,562 | 18,187,237 | 1.2 |  |
| 6 | 1.3 | Cerramiento provisional con maletines, colombinas y cadenas plásticas |  | 35d | 2021-10-09 | 2021-11-04 | 5SS+6d | 2021-08-02 | 2021-08-27 | 35d | 5d | 0d |  | Etapa de preconstrucción [1814%] | 18,140,850 | 18,140,850 | 1.3 |  |
| 7 | 1.4 | Señalizacion preventiva y protecciones generales |  | 35d | 2021-10-14 | 2021-11-09 | 6SS+6d | 2021-08-02 | 2021-08-27 | 35d | 5d | 0d |  | Etapa de preconstrucción [761%] | 7,608,814 | 7,608,814 | 1.4 | un |
| 8 | 1.5 | Fin Preliminares | milestone | 0d | 2022-06-28 | 2022-06-28 | 4 | 2022-04-25 | 2022-04-25 | 0d | 237d |  |  |  |  |  | Hito |  |
| 9 | 2 | **EXPLANACIONES Y TRASLADO DE REDES** |  | 259d | 2021-10-14 | 2022-05-02 |  | 2021-08-02 | 2021-12-04 | 168d | 20d |  |  |  | 49,372,955,354 | 28,947,849,449 |  |  |
| 10 | 2.1 | **TRABAJOS PRELIMINARES** |  | 259d | 2021-10-14 | 2022-05-02 |  | 2021-08-02 | 2021-12-04 | 168d | 20d |  |  |  | 26,424,610,804 | 7,811,260,840 | 2.1 |  |
| 11 | 2.1.1 | **DEMOLICIÓN Y REMOCIÓN** |  | 244d | 2021-10-25 | 2022-05-02 |  | 2021-08-02 | 2021-09-15 | 60d | 5d |  |  |  | 552,354,186 | 89,979,248 | 2.1.1 |  |
| 12 | 2.1.1.1 | Demolición de pavimento de pisos y andenes de concreto |  | 244d | 2021-10-25 | 2022-05-02 | 7SS+15d | 2021-08-02 | 2021-09-15 | 60d | 5d | 0d |  | Etapa de preconstrucción | 467,210,877 | 4,835,939 | 2.1.1.1 | m2 |
| 13 | 2.1.1.2 | Demolición de caja de inspección |  | 30d | 2021-10-29 | 2021-11-20 | 12SS+5d | 2021-08-02 | 2021-08-24 | 30d | 5d | 0d |  | Etapa de preconstrucción [3782%] | 37,822,200 | 37,822,200 | 2.1.1.2 | un |
| 14 | 2.1.1.3 | Demolición de caja de inspección doble |  | 30d | 2021-10-29 | 2021-11-20 | 13SS | 2021-08-02 | 2021-08-24 | 30d | 5d | 0d |  | Etapa de preconstrucción [229%] | 2,289,034 | 2,289,034 | 2.1.1.3 | un |
| 15 | 2.1.1.4 | Desmonte cable baliza |  | 45d | 2021-10-29 | 2021-12-01 | 14SS | 2021-08-02 | 2021-09-04 | 45d | 5d | 0d |  | Etapa de preconstrucción [4%] | 42,451 | 42,451 | 2.1.1.4 | un |
| 16 | 2.1.2 | **REPOSICIÓN RED MEDIA TENSIÓN** |  | 40d | 2021-10-14 | 2021-11-12 |  | 2021-08-02 | 2021-08-31 | 40d | 383d |  |  |  | 36,302,710 | 36,302,710 |  |  |
| 17 | 2.1.2.1 | Caja de Inspección CS-276 |  | 40d | 2021-10-14 | 2021-11-12 | 7SS | 2021-08-02 | 2021-08-31 | 40d | 383d | 0d |  | Etapa de preconstrucción [1815%] | 18,151,355 | 18,151,355 | 2.1.2.1 | un |
| 18 | 2.1.3 | **REPOSICIÓN RED VOZ Y DATOS** |  | 90d | 2021-11-13 | 2022-01-23 |  | 2021-08-02 | 2021-10-07 | 90d | 383d |  |  |  | 394,064,074 | 394,064,074 |  |  |
| 19 | 2.1.3.1 | Línea de voz y datos |  | 90d | 2021-11-13 | 2022-01-23 | 17 | 2021-08-02 | 2021-10-07 | 90d | 383d | 0d |  | Etapa de preconstrucción [18202%] | 182,016,733 | 182,016,733 | 2.1.3.1 |  |
| 20 | 2.1.3.2 | Caja de inspección cs-275 |  | 60d | 2021-11-13 | 2021-12-29 | 19SS | 2021-08-02 | 2021-09-15 | 60d | 383d | 0d |  | Etapa de preconstrucción [238%] | 2,377,776 | 2,377,776 | 2.1.3.2 | un |
| 21 | 2.1.3.3 | Caja de inspección cs-280 |  | 60d | 2021-11-13 | 2021-12-29 | 20SS | 2021-08-02 | 2021-09-15 | 60d | 383d | 0d |  | Etapa de preconstrucción [1264%] | 12,637,528 | 12,637,528 | 2.1.3.3 | un |
| 22 | 2.1.4 | **REPOSICION RED SANEAMIENTO** |  | 150d | 2021-10-29 | 2022-02-22 |  | 2021-08-02 | 2021-12-04 | 168d | 403d |  |  |  | 21,101,294,506 | 3,655,022,036 | 2.1.4 |  |
| 23 | 2.1.4.1 | Instalacion válvula de compuerta marca apco crf dn 250 - pn 16 |  | 30d | 2021-11-19 | 2021-12-11 | 28SS | 2021-08-02 | 2021-08-02 | 0d | 404d | 1d |  | Etapa de preconstrucción | 510,134,300 |  | 2.1.4.1 | un |
| 24 | 2.1.4.2 | Válvula de cheque marca apco, modelo 100r, dn 10 instalacion |  | 40d | 2021-11-16 | 2021-12-16 | 129SS-40d | 2021-08-18 | 2021-09-09 | 30d | 403d | 0d |  | Etapa de preconstrucción [2244%] | 22,441,196 | 22,441,196 | 2.1.4.2 | un |
| 25 | 2.1.4.3 | Válvula combinada de aire para alcantarillado marca apco, scav serie 440 - 2 x 7/32 instalacion |  | 30d | 2021-11-17 | 2021-12-09 | 24SS+1d | 2021-08-18 | 2021-09-09 | 30d | 403d | 0d |  | Etapa de preconstrucción [1134%] | 11,336,514 | 39,677,799 | 2.1.4.3 | un |
| 26 | 2.1.4.4 | Válvula de compuerta marca apco pec dn 150 - pn 16 instalacion |  | 30d | 2021-11-18 | 2021-12-10 | 25SS+1d | 2021-08-18 | 2021-09-09 | 30d | 403d | 0d |  | Etapa de preconstrucción [701%] | 7,008,070 | 14,016,140 | 2.1.4.4 | un |
| 27 | 2.1.4.5 | Valvula alivio presion apco, serie 3000, modelo 3006 (diametro 6) instalacion |  | 30d | 2021-11-19 | 2021-12-11 | 26SS+1d | 2021-08-18 | 2021-09-09 | 30d | 403d | 0d |  | Etapa de preconstrucción [1506%] | 15,063,850 | 15,063,850 | 2.1.4.5 | un |
| 28 | 2.1.4.6 | Instalacion válvula de tapón apco hd ø 14” bridada |  | 30d | 2021-11-19 | 2021-12-11 | 27SS+1d | 2021-08-18 | 2021-09-09 | 30d | 403d | 0d |  | Etapa de preconstrucción [2066%] | 20,658,716 | 41,317,432 | 2.1.4.6 | un |
| 29 | 2.1.4.7 | Instalacion válvula de tapón apco hd ø 18” bridada |  | 30d | 2021-11-20 | 2021-12-12 | 28SS+1d, 23SS | 2021-08-18 | 2021-09-09 | 30d | 403d | 0d |  | Etapa de preconstrucción [1685%] | 16,852,198 | 16,852,198 | 2.1.4.7 | un |
| 30 | 2.1.4.8 | Instalacion válvula de tapón apco hd ø 8” bridada |  | 30d | 2021-11-21 | 2021-12-13 | 29SS+1d | 2021-08-18 | 2021-09-09 | 30d | 403d | 0d |  | Etapa de preconstrucción [343%] | 3,433,785 | 3,433,785 | 2.1.4.8 | un |
| 31 | 2.1.4.9 | Instalacion abrazadera ø 14” |  | 30d | 2021-11-22 | 2021-12-14 | 30SS+1d | 2021-08-18 | 2021-09-09 | 30d | 403d | 0d |  | Etapa de preconstrucción [28%] | 284,640 | 284,640 | 2.1.4.9 | un |
| 32 | 2.1.4.10 | Instalacion codo 12.5” hd ø14” junta rápida |  | 30d | 2021-11-22 | 2021-12-14 | 31SS | 2021-11-07 | 2021-11-07 | 0d | 404d | 0d |  | Etapa de preconstrucción | 506,206,816 |  | 2.1.4.10 | un |
| 33 | 2.1.4.11 | Instalacion codo 22.5” hd ø6” brida*brida |  | 30d | 2021-11-22 | 2021-12-14 | 32SS | 2021-11-07 | 2021-11-07 | 0d | 404d | 0d |  | Etapa de preconstrucción | 500,705,404 |  | 2.1.4.11 | un |
| 34 | 2.1.4.12 | Instalacion codo 45” hd ø10” brida*brida |  | 30d | 2021-11-22 | 2021-12-14 | 33SS | 2021-11-07 | 2021-11-07 | 0d | 404d | 0d |  | Etapa de preconstrucción | 501,990,968 |  | 2.1.4.12 | un |
| 35 | 2.1.4.13 | Instalacion codo 90” hd ø6” brida*brida |  | 30d | 2021-11-22 | 2021-12-14 | 34SS | 2021-11-07 | 2021-11-07 | 0d | 404d | 0d |  | Etapa de preconstrucción | 501,502,900 |  | 2.1.4.13 | un |
| 36 | 2.1.4.14 | Instalacion codo 90” hd ø6” junta rápida |  | 30d | 2021-11-22 | 2021-12-14 | 35SS | 2021-11-07 | 2021-11-07 | 0d | 404d | 0d |  | Etapa de preconstrucción | 501,674,186 |  | 2.1.4.14 | un |
| 37 | 2.1.4.15 | Instalacion codo pvc sanitario 90” ø3” |  | 30d | 2021-11-22 | 2021-12-14 | 36SS | 2021-11-07 | 2021-11-07 | 0d | 404d | 0d |  | Etapa de preconstrucción | 500,064,035 |  | 2.1.4.15 | un |
| 38 | 2.1.4.16 | Instalacion manómetro conexión vertical ø3/4” |  | 30d | 2021-12-03 | 2021-12-28 | 80SS+1d | 2021-09-08 | 2021-09-30 | 30d | 403d | 0d |  | Etapa de preconstrucción [11%] | 113,019 | 113,019 | 2.1.4.16 | un |
| 39 | 2.1.4.17 | Instalacion niple 14” hd i=80cm ext brida x ext bridada |  | 30d | 2021-11-22 | 2021-12-14 | 37SS | 2021-11-07 | 2021-11-07 | 0d | 404d | 0d |  | Etapa de preconstrucción | 504,433,060 |  | 2.1.4.17 | un |
| 40 | 2.1.4.18 | Instalacion niple ø10” hd i=110cm ext brida x ext bridada |  | 30d | 2021-11-22 | 2021-12-14 | 39SS | 2021-11-07 | 2021-11-07 | 0d | 404d | 1d |  | Etapa de preconstrucción | 502,979,520 |  | 2.1.4.18 | un |
| 41 | 2.1.4.19 | Instalacion niple ø6” hd i=110cm ext brida x ext bridada |  | 30d | 2021-11-22 | 2021-12-15 | 31SS+1d, 40SS | 2021-08-18 | 2021-09-09 | 30d | 403d | 0d |  | Etapa de preconstrucción [74%] | 738,664 | 738,664 | 2.1.4.19 | un |
| 42 | 2.1.4.20 | Instalacion niple ø6” hd i=40cm ext brida x ext bridada |  | 30d | 2021-11-23 | 2021-12-15 | 41SS+1d | 2021-08-18 | 2021-09-09 | 30d | 403d | 0d |  | Etapa de preconstrucción [124%] | 1,236,534 | 1,236,534 | 2.1.4.20 | un |
| 43 | 2.1.4.21 | Instalacion pasamuro ø14” hd l=85 cm ext brida x ext brida |  | 30d | 2021-11-23 | 2021-12-15 | 42SS | 2021-11-07 | 2021-11-07 | 0d | 404d | 0d |  | Etapa de preconstrucción | 504,497,298 |  | 2.1.4.21 | un |
| 44 | 2.1.4.22 | Instalacion pasamuro ø6” hd l=50 cm ext brida x ext brida |  | 30d | 2021-11-23 | 2021-12-15 | 43SS | 2021-11-07 | 2021-11-07 | 0d | 404d | 0d |  | Etapa de preconstrucción | 503,158,976 |  | 2.1.4.22 | un |
| 45 | 2.1.4.23 | Instalacion pasamuro ø10” hd l=50 cm ext brida x ext brida |  | 30d | 2021-11-23 | 2021-12-15 | 44SS | 2021-11-07 | 2021-11-07 | 0d | 404d | 0d |  | Etapa de preconstrucción | 502,832,022 |  | 2.1.4.23 | un |
| 46 | 2.1.4.24 | Instalacion pasamuro ø14” hd l=40 cm ext brida x ext brida |  | 30d | 2021-11-23 | 2021-12-15 | 45SS | 2021-11-07 | 2021-11-07 | 0d | 404d | 1d |  | Etapa de preconstrucción | 502,998,612 |  | 2.1.4.24 | un |
| 47 | 2.1.4.25 | Instalacion pasamuro ø14” hd l=50 cm ext brida x ext brida |  | 30d | 2021-11-24 | 2021-12-16 | 42SS+1d, 46SS | 2021-08-18 | 2021-09-09 | 30d | 403d | 0d |  | Etapa de preconstrucción [753%] | 7,528,856 | 7,528,856 | 2.1.4.25 | un |
| 48 | 2.1.4.26 | Instalacion pasamuro ø14” hd l=70 cm ext brida x ext brida |  | 30d | 2021-11-24 | 2021-12-16 | 47SS | 2021-11-07 | 2021-11-07 | 0d | 404d | 0d |  | Etapa de preconstrucción | 504,069,434 |  | 2.1.4.26 | un |
| 49 | 2.1.4.27 | Instalacion pasamuro ø18” hd l=50 cm ext brida x ext brida |  | 30d | 2021-11-24 | 2021-12-16 | 48SS | 2021-11-07 | 2021-11-07 | 0d | 404d | 0d |  | Etapa de preconstrucción | 505,112,974 |  | 2.1.4.27 | un |
| 50 | 2.1.4.28 | Instalacion pasamuro ø3” hd l=40 cm ext liso ext liso |  | 30d | 2021-11-24 | 2021-12-16 | 49SS | 2021-11-07 | 2021-11-07 | 0d | 404d | 0d |  | Etapa de preconstrucción | 500,411,502 |  | 2.1.4.28 | un |
| 51 | 2.1.4.29 | Instalacion pasamuro ø3” hd l=50 cm ext liso ext liso |  | 30d | 2021-11-24 | 2021-12-16 | 50SS | 2021-11-07 | 2021-11-07 | 0d | 404d | 0d |  | Etapa de preconstrucción | 500,617,253 |  | 2.1.4.29 | un |
| 52 | 2.1.4.30 | Instalacion reducción hd 10”x6” bridada |  | 30d | 2021-11-24 | 2021-12-16 | 51SS | 2021-11-07 | 2021-11-07 | 0d | 404d | 1d |  | Etapa de preconstrucción | 501,300,304 |  | 2.1.4.30 | un |
| 53 | 2.1.4.31 | Instalacion reducción hd 14” x 10” bridada |  | 30d | 2021-11-25 | 2021-12-17 | 47SS+1d, 52SS | 2021-08-18 | 2021-09-09 | 30d | 403d | 0d |  | Etapa de preconstrucción [292%] | 2,924,756 | 5,849,512 | 2.1.4.31 | un |
| 54 | 2.1.4.32 | Instalacion tee reducida ø 14” x 4” hd bridada |  | 30d | 2021-11-25 | 2021-12-17 | 53SS | 2021-11-07 | 2021-11-07 | 0d | 404d | 1d |  | Etapa de preconstrucción | 504,691,030 |  | 2.1.4.32 | un |
| 55 | 2.1.4.33 | Instalacion tee partida ø 14” x 6” hd bridada |  | 30d | 2021-11-25 | 2021-12-17 | 53SS+1d, 54SS | 2021-08-18 | 2021-09-20 | 45d | 403d | 0d |  | Etapa de preconstrucción [538%] | 5,381,842 | 5,381,842 | 2.1.4.33 | un |
| 56 | 2.1.4.34 | Instalacion tee partida ø 18” x 8” hd bridada |  | 30d | 2021-11-26 | 2021-12-18 | 55SS+1d | 2021-08-18 | 2021-09-20 | 45d | 403d | 0d |  | Etapa de preconstrucción [377%] | 3,767,288 | 3,767,288 | 2.1.4.34 | un |
| 57 | 2.1.4.35 | Instalacion tee reducida ø 10” x 4” hd bridada |  | 30d | 2021-11-27 | 2021-12-19 | 56SS+1d | 2021-08-18 | 2021-09-20 | 45d | 403d | 0d |  | Etapa de preconstrucción [315%] | 3,151,296 | 3,151,296 | 2.1.4.35 | un |
| 58 | 2.1.4.36 | Instalacion tee reducida ø 10” x 6” hd bridada |  | 30d | 2021-11-27 | 2021-12-20 | 57SS+1d | 2021-08-18 | 2021-09-20 | 45d | 403d | 0d |  | Etapa de preconstrucción [315%] | 3,151,296 | 3,151,296 | 2.1.4.36 | un |
| 59 | 2.1.4.37 | Instalacion tee reducida ø 14” x 6” hd bridada |  | 30d | 2021-11-28 | 2021-12-21 | 58SS+1d | 2021-08-18 | 2021-09-20 | 45d | 403d | 0d |  | Etapa de preconstrucción [559%] | 5,587,980 | 11,175,960 | 2.1.4.37 | un |
| 60 | 2.1.4.38 | Instalacion tee reducida ø 18” x 8” hd bridada |  | 30d | 2021-11-28 | 2021-12-21 | 59SS | 2021-11-07 | 2021-11-07 | 0d | 404d | 0d |  | Etapa de preconstrucción | 504,380,686 |  | 2.1.4.38 | un |
| 61 | 2.1.4.39 | Instalacion tubería hd 250mm dn |  | 30d | 2021-11-28 | 2021-12-21 | 60SS | 2021-11-07 | 2021-11-07 | 0d | 404d | 1d |  | Etapa de preconstrucción | 506,992,763 |  | 2.1.4.39 | un |
| 62 | 2.1.4.40 | Instalacion unión de montaje autoportante ø 18” |  | 30d | 2021-11-29 | 2021-12-21 | 59SS+1d, 61SS | 2021-08-18 | 2021-09-20 | 45d | 403d | 0d |  | Etapa de preconstrucción [778%] | 7,783,386 | 3,891,693 | 2.1.4.40 | un |
| 63 | 2.1.4.41 | Instalacion unión hd brida x acople universal ø 10” |  | 30d | 2021-11-29 | 2021-12-21 | 62SS | 2021-11-07 | 2021-11-07 | 0d | 404d | 1d |  | Etapa de preconstrucción | 501,495,528 |  | 2.1.4.41 | un |
| 64 | 2.1.4.42 | Instalacion unión hd brida x acople universal ø 14” |  | 30d | 2021-11-30 | 2021-12-22 | 62SS+1d, 63SS | 2021-08-18 | 2021-09-20 | 45d | 403d | 0d |  | Etapa de preconstrucción [517%] | 5,166,204 | 6,888,272 | 2.1.4.42 | un |
| 65 | 2.1.4.43 | Instalacion unión hd brida x acople universal ø 18” |  | 30d | 2021-12-01 | 2021-12-23 | 64SS+1d | 2021-08-18 | 2021-09-20 | 45d | 403d | 0d |  | Etapa de preconstrucción [281%] | 2,806,882 | 2,806,882 | 2.1.4.43 | un |
| 66 | 2.1.4.44 | Instalacion unión hd brida x acople universal ø 6” |  | 30d | 2021-12-01 | 2021-12-23 | 65SS | 2021-11-07 | 2021-11-07 | 0d | 404d | 1d |  | Etapa de preconstrucción | 501,757,064 |  | 2.1.4.44 | un |
| 67 | 2.1.4.45 | Instalacion unión de montaje autoportante ø 14” |  | 30d | 2021-12-01 | 2021-12-23 | 65SS+1d, 66SS | 2021-08-18 | 2021-09-20 | 45d | 403d | 0d |  | Etapa de preconstrucción [416%] | 4,162,432 | 6,243,648 | 2.1.4.45 | un |
| 68 | 2.1.4.46 | Instalacion unión de montaje autoportante ø 10” brida x brida |  | 30d | 2021-12-02 | 2021-12-26 | 67SS+1d | 2021-08-18 | 2021-09-20 | 45d | 403d | 0d |  | Etapa de preconstrucción [244%] | 2,436,680 | 2,436,680 | 2.1.4.46 | un |
| 69 | 2.1.4.47 | Instalacion juego de tornillería – empaque br 18 cl 125 delta |  | 30d | 2021-12-03 | 2021-12-27 | 68SS+1d | 2021-08-18 | 2021-09-20 | 45d | 408d | 0d |  | Etapa de preconstrucción [206%] | 2,058,306 | 2,058,306 | 2.1.4.47 | un |
| 70 | 2.1.4.48 | Instalacion juego de tornillería – empaque br 14 cl 125 delta |  | 30d | 2021-12-03 | 2021-12-28 | 69SS+1d | 2021-08-18 | 2021-09-20 | 45d | 408d | 0d |  | Etapa de preconstrucción [895%] | 8,951,544 | 8,951,544 | 2.1.4.48 | un |

| ID | WBS | Task | Duration | Start | Finish | Predecessors | Baseline start | Baseline finish | Baseline duration | Total slack | Free slack | Resources | Cost | Baseline cost | Text3 | Un |
| --- | --- | --- | --- | --- | --- | --- | --- | --- | --- | --- | --- | --- | --- | --- | --- | --- |
| 71 | 2.1.4.49 | Instalacion juego de tornillería – empaque br 10 cl 125 delta | 45d | 2021-12-04 | 2022-01-11 | 70SS+1d | 2021-08-18 | 2021-09-20 | 45d | 408d | 0d | Etapa de preconstrucción [654%] | 6,537,828 | 6,537,828 | 2.1.4.49 | un |
| 72 | 2.1.4.50 | Instalacion juego de tornillería – empaque br 6 cl 125 g2 delta | 45d | 2021-12-05 | 2022-01-12 | 71SS+1d | 2021-08-18 | 2021-09-20 | 45d | 408d | 0d | Etapa de preconstrucción [332%] | 3,320,548 | 3,320,548 | 2.1.4.50 | un |
| 73 | 2.1.4.51 | Instalacion juego de tornillería – empaque br 4 cl 125 g2 delta | 20d | 2021-12-06 | 2021-12-21 | 72SS+1d | 2021-08-18 | 2021-09-01 | 20d | 408d | 0d | Etapa de preconstrucción [31%] | 309,138 | 309,138 | 2.1.4.51 | un |
| 74 | 2.1.4.52 | Plan de contingencia extremo durante 45 dias. obras de desvió red 14 | 51d | 2022-01-15 | 2022-02-22 | 78FS-28d | 2021-11-01 | 2021-12-04 | 45d | 403d | 43d | Etapa de preconstrucción [40370%] | 403,703,065 | 403,703,065 | 2.1.4.52 | un |
| 75 | 2.1.4.53 | Cortes y empalmes tuberia red alcantarillado 14" | 15d | 2022-01-24 | 2022-02-04 | 73FS+40d | 2021-08-18 | 2021-08-25 | 10d | 408d | 0d | Etapa de preconstrucción [22050%] | 220,502,565 | 441,005,130 | 2.1.4.53 | un |
| 76 | 2.1.4.54 | Bombeo de aguas en 4” | 65d | 2021-12-23 | 2022-02-15 | 73FS+4d | 2021-09-02 | 2021-11-07 | 90d | 411d | 0d | Etapa de preconstrucción [2343%] | 23,430,000 | 23,430,000 | 2.1.4.54 | hr |
| 77 | 2.1.4.55 | Bombeo de aguas en 6” | 65d | 2021-12-27 | 2022-02-16 | 76SS+2d | 2021-09-02 | 2021-11-07 | 90d | 411d |  | Etapa de preconstrucción [3012%] | 30,124,800 | 30,124,800 | 2.1.4.55 | hr |
| 78 | 2.1.4.56 | Prueba de presión en tubería de 14 | 14d | 2022-01-26 | 2022-02-05 | 38SS+65d | 2021-10-22 | 2021-11-02 | 15d | 403d | 0d | Etapa de preconstrucción [858%] | 8,575,532 | 8,575,532 | 2.1.4.56 | un |
| 79 | 2.1.4.57 | Suministro codo 45° hd ø14” junta rápida (acoplable a tubería pvc) | 15d | 2021-10-29 | 2021-11-09 | 24SS-25d | 2021-11-07 | 2021-11-07 | 0d | 520d | 112d | Etapa de preconstrucción | 522,753,280 |  | 2.1.4.57 | un |
| 80 | 2.1.4.58 | Suministro manómetro conexión vertical ø3/4” | 3d | 2021-12-03 | 2021-12-05 | 68SS+1d | 2021-09-08 | 2021-09-10 | 3d | 403d | 0d | Etapa de preconstrucción [158%] | 1,578,618 | 1,578,618 | 2.1.4.58 | un |
| 81 | 2.1.4.59 | Suministro pasamuro ø14” hd l=50 cm ext brida x ext brida | 20d | 2022-01-25 | 2022-02-09 | 75SS+1d, 79SS | 2021-08-18 | 2021-09-09 | 30d | 408d | 0d | Etapa de preconstrucción [2294%] | 22,941,200 | 22,941,200 | 2.1.4.59 | un |
| 82 | 2.1.4.60 | Suministro reducción hd 14” x 10” bridada | 20d | 2022-01-26 | 2022-02-09 | 81SS+1d | 2021-08-18 | 2021-09-09 | 30d | 408d | 0d | Etapa de preconstrucción [647%] | 6,469,290 | 12,938,580 | 2.1.4.60 | un |
| 83 | 2.1.4.61 | Suministro unión hd brida x acople universal ø 14” | 20d | 2022-01-26 | 2022-02-10 | 82SS+1d | 2021-08-18 | 2021-09-09 | 30d | 408d | 0d | Etapa de preconstrucción [3303%] | 33,031,728 | 16,515,864 | 2.1.4.61 | un |
| 84 | 2.1.4.62 | Suministro – empaque br 14 cl 125 delta | 20d | 2022-01-27 | 2022-02-11 | 83SS+1d | 2021-08-18 | 2021-09-09 | 30d | 408d | 0d | Etapa de preconstrucción [288%] | 2,878,456 | 2,878,456 | 2.1.4.62 | un |
| 85 | 2.1.4.63 | Suministro – empaque br 10 cl 125 delta | 20d | 2022-01-28 | 2022-02-11 | 84SS+1d | 2021-08-18 | 2021-09-09 | 30d | 408d | 0d | Etapa de preconstrucción [70%] | 703,770 | 703,770 | 2.1.4.63 | un |
| 86 | 2.1.4.64 | Suministro – empaque br 6 cl 125 g2 delta | 20d | 2022-01-28 | 2022-02-12 | 85SS+1d | 2021-08-18 | 2021-09-09 | 30d | 408d | 0d | Etapa de preconstrucción [53%] | 527,608 | 527,608 | 2.1.4.64 | un |
| 87 | 2.1.4.65 | Suministro – empaque br 4 cl 125 g2 delta | 15d | 2022-01-29 | 2022-02-09 | 86SS+1d | 2021-08-18 | 2021-09-09 | 30d | 408d | 0d | Etapa de preconstrucción [9%] | 90,422 | 90,422 | 2.1.4.65 | un |
| 88 | 2.1.4.66 | Suministro juego de tornillería – empaque br 14 cl 125 delta | 15d | 2022-01-30 | 2022-02-10 | 87SS+1d | 2021-08-18 | 2021-09-09 | 30d | 408d | 0d | Etapa de preconstrucción [1147%] | 11,472,734 | 11,472,734 | 2.1.4.66 | un |
| 89 | 2.1.4.67 | Suministro juego de tornillería – empaque br 10 cl 125 delta | 15d | 2022-01-31 | 2022-02-11 | 88SS+1d | 2021-08-18 | 2021-09-09 | 30d | 408d | 0d | Etapa de preconstrucción [154%] | 1,536,084 | 1,536,084 | 2.1.4.67 | un |
| 90 | 2.1.4.68 | Suministro juego de tornillería – empaque br 6 cl 125 g2 delta | 15d | 2022-02-01 | 2022-02-11 | 89SS+1d | 2021-08-18 | 2021-09-09 | 30d | 408d | 0d | Etapa de preconstrucción [28%] | 276,336 | 276,336 | 2.1.4.68 | un |
| 91 | 2.1.4.69 | Suministro juego de tornillería – empaque br 4 cl 125 g2 delta | 15d | 2022-02-01 | 2022-02-12 | 90SS+1d | 2021-08-18 | 2021-09-09 | 30d | 408d | 0d | Etapa de preconstrucción [11%] | 112,012 | 112,012 | 2.1.4.69 | un |
| 92 | 2.1.4.70 | Reposición lechos de secado existentes | 15d | 2022-02-01 | 2022-02-12 | 91SS | 2021-11-07 | 2021-11-07 | 0d | 411d | 0d | Etapa de preconstrucción | 580,796,650 |  | 2.1.4.70 | m2 |
| 93 | 2.1.4.71 | Suministro válvula de tapón apco hd ø 6” bridada | 15d | 2022-02-01 | 2022-02-12 | 92SS | 2021-11-07 | 2021-11-07 | 0d | 411d | 0d | Etapa de preconstrucción | 506,946,132 |  | 2.1.4.71 | un |
| 94 | 2.1.4.72 | Suministro e inst. niple ø14” hd l=46cm ext brida x ext. bridada | 20d | 2022-02-01 | 2022-02-16 | 93SS | 2021-11-07 | 2021-11-07 | 0d | 411d | 0d | Etapa de preconstrucción | 508,850,668 |  | 2.1.4.72 | un |
| 95 | 2.1.4.73 | Suministro e inst. pasamuro ø14” hd l=60 cm ext brida x ext brida | 20d | 2022-02-01 | 2022-02-16 | 94SS | 2021-11-07 | 2021-11-07 | 0d | 411d | 0d | Etapa de preconstrucción | 531,730,148 |  | 2.1.4.73 | un |
| 96 | 2.1.4.74 | Suministro tee reducida ø10 x ø6 bxb hd , ansi clase 150 | 20d | 2022-02-02 | 2022-02-17 | 91SS+1d | 2021-08-18 | 2021-09-09 | 30d | 408d | 0d | Etapa de preconstrucción [977%] | 9,772,848 | 9,772,848 | 2.1.4.74 | un |
| 97 | 2.1.4.75 | Suministro tee reducida ø14 x ø6 bxb hd, ansi clase 150 | 20d | 2022-02-03 | 2022-02-17 | 96SS+1d | 2021-08-18 | 2021-09-09 | 30d | 408d | 0d | Etapa de preconstrucción [1559%] | 15,594,974 | 31,189,948 | 2.1.4.75 | un |
| 98 | 2.1.4.76 | Suministro unión tipo dresser r1-r1 ø14" hd | 20d | 2022-02-03 | 2022-02-18 | 97SS+1d | 2021-08-18 | 2021-09-09 | 30d | 408d | 0d | Etapa de preconstrucción [1494%] | 14,944,992 | 3,736,248 | 2.1.4.76 | un |
| 99 | 2.1.4.77 | Suministro e instalación unión de reparación ø14" | 20d | 2022-02-03 | 2022-02-18 | 98SS | 2021-11-07 | 2021-11-07 | 0d | 408d | 0d | Etapa de preconstrucción | 516,307,040 |  | 2.1.4.77 | un |
| 100 | 2.1.4.78 | Suministro e instalación unión rápida (unión z) ø14" | 20d | 2022-02-03 | 2022-02-18 | 99SS | 2021-11-07 | 2021-11-07 | 0d | 408d | 0d | Etapa de preconstrucción | 508,153,520 |  | 2.1.4.78 | un |
| 101 | 2.1.4.79 | Relleno en arena de peña para redes (incluye suministro, humedecimiento y compactación) | 20d | 2022-02-03 | 2022-02-18 | 100SS | 2021-11-07 | 2021-11-07 | 0d | 408d | 0d | Etapa de preconstrucción | 539,599,517 |  | 2.1.4.79 | m3 |
| 102 | 2.1.4.80 | Suministro e instalación tubería biaxial pvc 14 tipo rde 37 | 20d | 2022-02-03 | 2022-02-18 | 98SS, 101SS | 2021-08-18 | 2021-09-09 | 30d | 408d | 0d | Etapa de preconstrucción [6583%] | 65,830,545 | 51,115,482 | 2.1.4.80 |  |
| 103 | 2.1.4.81 | Sacos prolipropileno de 0.92m x 0.60 m para contenciòn y apoyo tuberias | 20d | 2022-02-03 | 2022-02-18 | 102SS | 2021-11-07 | 2021-11-07 | 0d | 408d | 0d | Etapa de preconstrucción | 527,867,300 |  | 2.1.4.81 | m3 |
| 104 | 2.1.4.82 | Entibado metalico tipo krings | 20d | 2022-02-03 | 2022-02-18 | 103SS | 2021-11-07 | 2021-11-07 | 0d | 408d |  | Etapa de preconstrucción | 521,016,068 |  | 2.1.4.82 | m2/dia |
| 105 | 2.1.4.83 | Instalación soporte tubería red contraincendios | 50d | 2021-12-04 | 2022-01-15 | 71SS | 2021-11-07 | 2021-11-07 | 0d | 409d | 0d | Etapa de preconstrucción | 520,074,288 |  | 2.1.4.83 | un |
| 106 | 2.1.4.84 | Instalación tuberìa biaxial pvc 14 tipo rde 37 | 50d | 2021-12-04 | 2022-01-15 | 105SS | 2021-08-18 | 2021-10-01 | 60d | 409d | 0d | Etapa de preconstrucción [4030%] | 40,299,714 | 21,109,374 | 2.1.4.84 |  |
| 107 | 2.1.4.85 NP | Suministro e Instalación de tubería PEAD 400mm SDR 13.5 | 60d | 2021-12-08 | 2022-01-26 | 106SS+5d | 2021-09-08 | 2021-10-22 | 60d | 409d | 0d |  | 401,288,256 | 31,359,104 | NP2.1.4.90 | un |
| 108 | 2.1.4.86 NP | Suministro e Instalación de tubería PEAD 315mm SDR 13.5 | 60d | 2021-12-08 | 2022-01-26 | 107SS | 2021-09-08 | 2021-10-22 | 60d | 409d | 0d |  | 149,974,638 | 8,102,156 | NP2.1.4.91 | un |
| 109 | 2.1.4.87 NP | Suministro e Instalación de tubería PEAD 110mm SDR 13.5 | 60d | 2021-12-08 | 2022-01-26 | 108SS | 2021-09-08 | 2021-10-22 | 60d | 409d | 0d |  | 9,912,880 | 2,248,664 | NP2.1.4.92 | un |
| 110 | 2.1.4.88 NP | Suministro e instalación codo PEAD 40mm 45° | 60d | 2021-12-08 | 2022-01-26 | 109SS | 2021-08-20 | 2021-10-04 | 60d | 409d | 0d |  | 25,453,424 | 4,479,012 | NP2.1.4.94 | un |
| 111 | 2.1.4.89 NP | Suministro e Instalación de tubería PEAD 160mm SDR 26 | 60d | 2021-12-08 | 2022-01-26 | 110SS | 2021-08-12 | 2021-09-25 | 60d | 409d | 0d |  | 71,340,338 | 1,964,987 | NP2.1.4.95 | un |
| 112 | 2.1.4.90 NP | Suministro e Instalación de junta flexible para tubería 14" | 60d | 2021-12-08 | 2022-01-26 | 111SS | 2021-08-10 | 2021-09-24 | 60d | 409d | 0d |  | 16,490,492 | 9,458,708 | NP2.1.4.96 | un |
| 113 | 2.1.4.91 NP | Suministro e Instalación de junta flexible para tubería 10" | 60d | 2021-12-08 | 2022-01-26 | 112SS | 2021-08-10 | 2021-09-24 | 60d | 409d | 0d |  | 3,830,914 | 1,106,955 | NP2.1.4.97 | un |
| 114 | 5.4.4.1 MC | Concreto clas C (incluye encofrado) | 50d | 2021-12-08 | 2022-01-19 | 113SS | 2021-08-10 | 2021-09-24 | 60d | 409d | 0d |  | 118,824,778 | 11,612,308 | NP2.1.4.98 | m3 |
| 115 | 5.5.1.2 MC | Concreto clase F | 50d | 2021-12-08 | 2022-01-19 | 114SS | 2021-08-10 | 2021-09-24 | 60d | 409d | 0d |  | 944,811 | 4,202,714 | NP2.1.4.99 | m3 |
| 116 | 5.4.3.2 MC | Acero de refuerzo (fy = 420 Mpa) | 50d | 2021-12-08 | 2022-01-19 | 115SS | 2021-08-10 | 2021-09-24 | 60d | 409d | 26d |  | 29,030,970 | 712,154 | NP2.1.4.100 | Kg |

| ID | WBS | Task | Type | Duration | Start | Finish | Predecessors | Baseline start | Baseline finish | Baseline duration | Total slack | Free slack | Resources | Cost | Baseline cost | Text3 | Un |
| --- | --- | --- | --- | --- | --- | --- | --- | --- | --- | --- | --- | --- | --- | --- | --- | --- | --- |
| 117 | 2.1.5 | **TRASLADO PROVISIONAL DE REDES SECAS SISTEMA ELECTRICO** |  | 90d | 2021-12-29 | 2022-03-09 |  | 2021-08-07 | 2021-10-14 | 92d | 383d |  |  | 441,544,272 | 441,544,272 | 2.1.5 |  |
| 118 | 2.1.5.1 | Suministro tubos ф 6" pvc , tipo TPD para ductos ø6" |  | 90d | 2021-12-29 | 2022-03-09 | 116SS, 21 | 2021-08-09 | 2021-10-14 | 90d | 383d | 0d | Etapa de preconstrucción [4720%] | 47,195,940 | 47,195,940 | 2.1.5.1 |  |
| 119 | 2.1.5.2 | Banco de ductos 4x6" pvc, tipo TPD areas con pavimento (No incluye suministro tubos pvc ø6" |  | 70d | 2021-12-29 | 2022-02-22 | 118SS | 2021-08-07 | 2021-09-28 | 70d | 393d | 0d | Etapa de preconstrucción [3553%] | 35,527,080 | 35,527,080 | 2.1.5.2 |  |
| 120 | 2.1.5.3 | Banco de ductos 4x6" pvc, tipo TPD areas no pavimento (No incluye suministro tubos pvc ø6" |  | 80d | 2021-12-29 | 2022-03-01 | 119SS | 2021-08-07 | 2021-10-06 | 80d | 393d | 0d | Etapa de preconstrucción [9199%] | 91,987,168 | 91,987,168 | 2.1.5.3 |  |
| 121 | 2.1.5.4 | Instalación tubería PVC 4" para drenaje de cajas eléctricas existentes (no incluye excavación, rellenos y disposición de material) |  | 20d | 2021-12-29 | 2022-01-16 | 120SS | 2021-08-07 | 2021-08-22 | 20d | 453d | 0d | Etapa de preconstrucción [9%] | 87,808 | 87,808 | 2.1.5.4 |  |
| 122 | 2.1.5.5 | Empalme MT para cable 4/0 Cu, 15KV, XLPE (Incluye suministro e instalación) |  | 20d | 2021-12-29 | 2022-01-16 | 121SS | 2021-08-07 | 2021-08-22 | 20d | 453d |  | Etapa de preconstrucción [4597%] | 45,974,140 | 45,974,140 | 2.1.5.5 |  |
| 123 | 2.1.6 | **REDES DE AGUAS RESIDUALES Y RED CONTRAINCENDIO** |  | 49d | 2021-12-15 | 2022-01-25 |  | 2021-08-02 | 2021-11-07 | 132d | 440d |  |  | 1,295,297,443 | 590,594,887 | 2.1.6 |  |
| 124 | 2.1.6.6 | Prueba de presión en tubería de 10" |  | 14d | 2022-01-15 | 2022-01-25 | 125FS+18d | 2021-10-22 | 2021-11-02 | 15d | 440d |  | Etapa de preconstrucción | 500,000,000 | 3,070,143 | 2.1.6.6 | un |
| 125 | 2.1.6.10 | INSTALACIÓN SOPORTE TUBERÍA RED CONTRAINCENDIOS |  | 17d | 2021-12-15 | 2021-12-30 | 107SS+10d | 2021-11-07 | 2021-11-07 | 0d | 440d | 0d | Etapa de preconstrucción | 500,000,000 |  | 2.1.6.10 | un |
| 126 | 2.2 | **EXCAVACIONES** |  | 145d | 2021-10-27 | 2022-02-16 |  | 2021-08-09 | 2021-10-16 | 92d | 21d |  |  | 6,928,165,734 | 7,807,248,168 | 2.2 |  |
| 127 | 2.2.1 | **EXCAVACIÓN DE LA EXPLANACIÓN** |  | 145d | 2021-10-27 | 2022-02-16 |  | 2021-08-09 | 2021-10-16 | 92d | 21d |  |  | 4,325,749,678 | 5,204,832,112 | 2.2.1 |  |
| 128 | 2.2.1.1 | Excavación sin clasificar de la explanación, retiro y disposicion |  | 133d | 2021-10-27 | 2022-02-07 | 6FS-12d | 2021-08-09 | 2021-10-14 | 90d | 33d | 28d | Etapa de preconstrucción [46816%] | 1,072,500,933 | 878,714,154 | 2.2.1.1 | m3 |
| 129 | 2.2.1.2 | Retiro de escombros a botadero certificado |  | 77d | 2021-12-16 | 2022-02-16 | 128SS+40d, 15FS+20d | 2021-08-10 | 2021-10-16 | 90d | 5d | 0d |  | 650,832,689 | 1,723,701,902 | 2.2.1.2 | m3 |
| 130 | 2.3 | **RELLENOS** |  | 139d | 2021-11-25 | 2022-03-12 |  | 2021-08-02 | 2021-10-29 | 120d | 5d |  |  | 6,747,168,724 | 4,591,200,054 | 2.3 |  |
| 131 | 2.3.1 | **TERRAPLENES** |  | 139d | 2021-11-25 | 2022-03-12 |  | 2021-08-02 | 2021-10-25 | 114d | 5d |  |  | 3,015,831,860 | 1,526,091,036 | 2.3.1 |  |
| 132 | 2.3.1.1 | Terraplenes. Núcleo. suelo adecuado |  | 63d | 2022-01-25 | 2022-03-12 | 129FS-30d, 135SS | 2021-08-02 | 2021-08-02 | 0d | 5d | 0d | Etapa de preconstrucción | 1,151,807,731 |  | 2.3.1.1 | m3 |
| 133 | 2.3.1.3 | Transporte de materiales petreos traidos de cantera |  | 60d | 2021-11-25 | 2022-01-13 | 138SS-28d | 2021-08-12 | 2021-10-25 | 100d | 80d | 0d | Etapa de preconstrucción [137867%] | 1,100,978,611 | 429,571,788 | 2.3.1.3 | m3 |
| 134 | 2.3.2 | **PEDRAPLENES** |  | 59d | 2021-11-25 | 2022-01-13 |  | 2021-08-16 | 2021-10-29 | 100d | 80d |  |  | 2,200,936,846 | 1,534,709,000 | 2.3.2 |  |
| 135 | 2.3.2.1 | Cimiento terraplen rajón compactado |  | 59d | 2021-11-25 | 2022-01-13 | 128SS+10d, 133SS+1d | 2021-08-16 | 2021-10-29 | 100d | 80d | 75d | Etapa de preconstrucción [30120%] | 1,433,582,346 | 767,354,500 | 2.3.2.1 | m3 |
| 136 | 2.4 | **OTRAS PARTIDAS COMPLEMENTARIAS** |  | 100d | 2021-12-15 | 2022-03-04 |  | 2021-08-10 | 2021-11-03 | 116d | 12d |  |  | 2,036,047,730 | 1,501,178,025 | 2.4 |  |
| 137 | 2.4.1 | **ESTABILIZACIÓN DE SUELOS DE SUBRASANTE Y CAPAS GRANULARES CON GEOTEXTILES** |  | 100d | 2021-12-15 | 2022-03-04 |  | 2021-08-10 | 2021-11-03 | 116d | 12d |  |  | 1,535,655,055 | 1,000,785,350 | 2.4.1 |  |
| 138 | 2.4.1.1 | Geomalla biaxial lbo 302 o similar.( inc. suministro e instalación) |  | 100d | 2021-12-15 | 2022-03-04 | 129SS-1d | 2021-08-10 | 2021-10-22 | 100d | 12d | 0d | Etapa de preconstrucción [49338%] | 647,350,880 | 307,334,544 | 2.4.1.1 | m2 |
| 139 | 2.4.1.2 | Geotextil no tejido 1600 |  | 100d | 2021-12-15 | 2022-03-04 | 138SS | 2021-08-21 | 2021-11-03 | 100d | 389d |  | Etapa de preconstrucción [13131%] | 387,911,500 | 193,058,131 | 2.4.1.2 | m2 |
| 140 | 2.5 | Fin redes | milestone | 0d | 2022-02-16 | 2022-02-16 | 74SS, 95 | 2021-11-07 | 2021-11-07 | 0d | 411d |  |  |  |  | Hito |  |

| ID | WBS | Task | Type | Duration | Start | Finish | Predecessors | Baseline start | Baseline finish | Baseline duration | Total slack | Free slack | Resources | Cost | Baseline cost | Text3 | Un |
| --- | --- | --- | --- | --- | --- | --- | --- | --- | --- | --- | --- | --- | --- | --- | --- | --- | --- |
| 141 | 3 | **AFIRMADOS, SUBBASES Y BASES** |  | 79d | 2022-02-22 | 2022-04-24 |  | 2021-08-20 | 2021-11-22 | 127d | 5d |  |  | 12,547,938,209 | 15,022,926,820 |  |  |
| 142 | 3.2 | **CAPAS GRANULARES DE BASE** |  | 79d | 2022-02-22 | 2022-04-24 |  | 2021-09-01 | 2021-11-22 | 110d | 5d |  |  | 8,792,206,504 | 8,399,949,927 | 3.2 |  |
| 143 | 3.2.1 | **BASE GRANULAR** |  | 79d | 2022-02-22 | 2022-04-24 |  | 2021-09-01 | 2021-11-22 | 110d | 5d |  |  | 5,992,223,195 | 5,599,966,618 | 3.2.1 |  |
| 144 | 3.2.1.1 | Capa de base de agregado triturado FAA p-209 |  | 79d | 2022-02-22 | 2022-04-24 | 132FS-25d | 2021-09-16 | 2021-11-22 | 90d | 5d | 0d | Etapa de preconstrucción [169579%] | 3,192,239,886 | 2,292,948,882 | 3.2.1.1 | m3 |
| 145 | 3.3 | Fin Afirmados, Subbases y Bases | milestone | 0d | 2022-04-24 | 2022-04-24 | 144 | 2021-11-22 | 2021-11-22 | 0d | 324d |  |  |  |  | Hito |  |
| 146 | 4 | **PAVIMENTOS ASFÁLTICOS** |  | 321d | 2022-03-16 | 2022-11-12 |  | 2021-08-25 | 2022-03-27 | 282d | 5d |  |  | 36,065,007,621 | 35,652,945,456 |  |  |
| 147 | 4.1 | **RIEGOS** |  | 127d | 2022-03-16 | 2022-06-21 |  | 2021-10-08 | 2022-01-10 | 120d | 5d |  |  | 891,701,861 | 915,440,121 | 4.1 |  |
| 148 | 4.1.1 | **RIEGO DE IMPRIMACIÓN** |  | 60d | 2022-03-16 | 2022-05-02 |  | 2021-10-08 | 2021-11-15 | 50d | 5d |  |  | 205,138,320 | 254,575,392 | 4.1.1 |  |
| 149 | 4.1.1.1 | Riego de imprimación con emulsión asfáltica |  | 60d | 2022-03-16 | 2022-05-02 | 144SS+30d | 2021-10-08 | 2021-11-15 | 50d | 5d | 0d | Etapa de preconstrucción [10713%] | 77,850,624 | 127,287,696 | 4.1.1.1 | m2 |
| 150 | 4.1.2 | **RIEGO DE LIGA** |  | 65d | 2022-05-04 | 2022-06-21 |  | 2021-11-22 | 2022-01-10 | 60d | 6d |  |  | 381,416,834 | 355,718,022 | 4.1.2 |  |
| 151 | 4.1.2.1 | Riego de liga con emulsión asfáltica faa p-603 |  | 65d | 2022-05-04 | 2022-06-21 | 155FS-1d | 2021-11-22 | 2022-01-10 | 60d | 6d | 1d | Etapa de preconstrucción [15632%] | 203,557,823 | 177,859,011 | 4.1.2.1 | m2 |
| 152 | 4.2 | **MEZCLAS ASFÁLTICAS EN CALIENTE AEROPUERTOS** |  | 129d | 2022-03-24 | 2022-06-30 |  | 2021-08-25 | 2022-02-02 | 210d | 5d |  |  | 24,798,064,803 | 24,179,506,266 | 4.2 |  |
| 153 | 4.2.1 | **MEZCLAS ASFÁLTICAS EN CALIENTE** |  | 129d | 2022-03-24 | 2022-06-30 |  | 2021-08-25 | 2022-02-02 | 210d | 5d |  |  | 16,738,229,381 | 16,119,670,844 | 4.2.1 |  |
| 154 | 4.2.1.1 | Pavimento bituminoso superficial elaborado en planta para capa de rodadura faa p -401 |  | 76d | 2022-05-05 | 2022-06-30 | 151SS, 155 | 2021-12-14 | 2022-02-02 | 60d | 5d | 0d | Etapa de preconstrucción [353024%] | 4,303,985,229 | 3,239,881,431 | 4.2.1.1 | m3 |
| 155 | 4.2.1.2 | Base estabilizada con asfalto en planta para capa base faa p-403 |  | 53d | 2022-03-24 | 2022-05-04 | 149SS+10d | 2021-11-15 | 2022-01-03 | 60d | 5d | 0d | Etapa de preconstrucción [411996%] | 4,374,408,730 | 4,646,845,205 | 4.2.1.2 | m3 |
| 156 | 4.3 | **MEZCLAS ASFÁLTICAS EN CALIENTE VIAS** |  | 21d | 2022-10-27 | 2022-11-12 |  | 2021-09-06 | 2022-03-27 | 266d | 0d |  |  | 1,462,004,593 | 1,644,762,705 | 4.3 |  |
| 157 | 4.3.1 | **MEZCLAS ASFÁLTICAS EN CALIENTE** |  | 21d | 2022-10-27 | 2022-11-12 |  | 2021-09-06 | 2022-03-27 | 266d | 0d |  |  | 913,750,358 | 1,096,508,470 | 4.3.1 |  |
| 158 | 4.3.1.2 | Mezcla densa en caliente tipo mdc-19, para capa intermedia |  | 21d | 2022-10-27 | 2022-11-12 | 185FS+101d | 2021-09-06 | 2021-09-06 | 0d | 0d |  | Etapa de preconstrucción | 365,496,123 |  | 4.3.1.2 | m3 |
| 159 | 4.4 | Fin Pavimentos Asfálticos | milestone | 0d | 2022-06-30 | 2022-06-30 | 154 | 2022-03-27 | 2022-03-27 | 0d | 234d |  |  |  |  | Hito |  |
| 160 | 5 | **ESTRUCTURAS Y ELEMENTOS DE CONTENCIÓN** |  | 374d | 2021-11-02 | 2022-08-13 |  | 2021-08-02 | 2022-08-06 | 489d | 0d |  |  | 116,058,158,313 | 137,685,518,740 |  |  |
| 161 | 5.1 | **EXCAVACIONES PARA ESTRUCTURAS** |  | 200d | 2021-11-02 | 2022-04-04 |  | 2022-01-25 | 2022-05-04 | 130d | 0d |  |  | 4,100,528,416 | 3,428,436,624 | 5.1 |  |
| 162 | 5.1.1 | **EXCAVACIONES VARIAS** |  | 200d | 2021-11-02 | 2022-04-04 |  | 2022-01-25 | 2022-05-04 | 130d | 0d |  |  | 2,957,716,208 | 2,285,624,416 | 5.1.1 |  |
| 163 | 5.1.1.1 | Excavaciones varias infraestructura |  | 200d | 2021-11-02 | 2022-04-04 | 1SS+43d | 2022-01-25 | 2022-05-04 | 130d | 0d |  | Etapa de preconstrucción [72583%] | 1,814,904,000 | 1,142,812,208 | 5.1.1.2 | m3 |
| 164 | 5.2 | **RELLENOS PARA ESTRUCTURAS** |  | 46d | 2022-04-02 | 2022-05-09 |  | 2022-07-28 | 2022-07-28 | 0d | 241d |  |  | 2,758,965,200 |  | 5.2 |  |
| 165 | 5.2.1 | **RELLENOS PARA ESTRUCTURAS** |  | 46d | 2022-04-02 | 2022-05-09 |  | 2022-07-28 | 2022-07-28 | 0d | 241d |  |  | 2,758,965,200 |  | 5.2.1 |  |
| 166 | 5.2.1.1 | Rellenos para estructuras |  | 26d | 2022-04-20 | 2022-05-09 | 167SS+20d | 2022-07-28 | 2022-07-28 | 0d | 241d | 0d | Etapa de preconstrucción | 1,403,019,650 |  | 5.2.1.1 | m3 |
| 167 | 5.2.1.2 NP | Suministro, transporte e instalación de elementos para muro mecánicamente estabilizado |  | 46d | 2022-04-02 | 2022-05-09 | 168SS |  |  |  | 241d | 0d |  | 802,861,857 |  |  | m2 |
| 168 | 5.4.4.1 MC | Concreto clase C (incluye encofrado) Muro tierra Armada |  | 46d | 2022-04-02 | 2022-05-09 | 169SS |  |  |  | 241d | 0d |  | 29,526,924 |  |  | m3 |
| 169 | 5.4.3.1 MC | Concreto clase A Muro tierra Armada |  | 46d | 2022-04-02 | 2022-05-09 | 170SS |  |  |  | 241d | 0d |  | 275,978,700 |  |  | m3 |
| 170 | 5.4.3.2 MC | Acero de refuerzo (fy = 420 Mpa) Muro tierra Armada |  | 46d | 2022-04-02 | 2022-05-09 | 171SS |  |  |  | 241d | 0d |  | 58,503,808 |  |  | kg |
| 171 | 2.4.1.2 MC | Geotextil no tejido 1600 Muro tierra Armada |  | 40d | 2022-04-02 | 2022-05-04 | 172SS |  |  |  | 241d | 0d |  | 11,434,808 |  |  | m2 |
| 172 | 5.2.1.3 NP | Construcción de gavion de 2x2 |  | 29d | 2022-04-02 | 2022-04-26 | 163FS-2d |  |  |  | 241d | 0d |  | 177,639,453 |  |  | m3 |

| ID | WBS | Task | Duration | Start | Finish | Predecessors | Baseline start | Baseline finish | Baseline duration | Total slack | Free slack | Resources | Cost | Baseline cost | Text3 | Un |
| --- | --- | --- | --- | --- | --- | --- | --- | --- | --- | --- | --- | --- | --- | --- | --- | --- |
| 173 | 5.3 | **CIMENTACIONES** | 199d | 2021-12-20 | 2022-05-24 |  | 2021-08-02 | 2022-07-28 | 477d | 0d |  |  | 14,034,990,421 | 14,074,453,995 | 5.3 |  |
| 174 | 5.3.1 | **BARRETES PREEXCAVADOS CENTRALES** | 60d | 2022-04-07 | 2022-05-24 |  | 2021-08-02 | 2022-07-28 | 477d | 0d |  |  | 2,160,376,145 | 1,968,662,934 | 5.3.1 |  |
| 175 | 5.3.1.2 NP | Perfilado y retiro de recubrimiento en estructuras existentes | 60d | 2022-04-07 | 2022-05-24 | 163FS+4d | 2021-08-02 | 2021-09-15 | 60d | 0d |  |  | 191,713,211 |  |  |  |
| 176 | 5.3.2 | **PANTALLAS DE HORMIGÓN PREEXCAVADAS** | 65d | 2021-12-20 | 2022-02-11 |  | 2021-08-02 | 2022-07-28 | 477d | 42d |  |  | 5,816,268,633 | 6,047,445,418 | 5.3.2 |  |
| 177 | 5.3.2.1 | Pantallas en concreto (barretes de 2.4mx0.8m) | 45d | 2022-01-08 | 2022-02-11 | 178SS+20d | 2021-08-27 | 2021-09-30 | 45d | 42d | 0d | Etapa de preconstrucción [576452%] | 1,467,713,180 | 1,567,181,617 | 5.3.2.1 |  |
| 178 | 5.4.3.2 MC | Acero de refuerzo fy=420 Mpa | 45d | 2021-12-20 | 2022-01-27 | 1SS+108d | 2021-08-12 | 2021-09-15 | 45d | 42d | 0d |  | 258,872,744 | 333,614,780 | NP | kg |
| 179 | 5.4 | **ESTRUCTURAS DE CONCRETO** | 357d | 2021-11-14 | 2022-08-13 |  | 2021-08-02 | 2022-07-28 | 477d | 155d |  |  | 59,759,527,206 | 85,867,800,210 | 5.4 |  |
| 180 | 5.4.3 | **LOSA SUPERIOR** | 161d | 2021-11-24 | 2022-03-28 |  | 2021-11-24 | 2022-01-27 | 80d | 327d |  |  | 7,152,907,801 | 8,790,711,769 | 5.4.3 |  |
| 181 | 5.4.3.1 | Concreto clase A | 95d | 2022-01-17 | 2022-03-28 | 182SS+66d, 183SS+30d, 188 | 2021-12-09 | 2022-01-27 | 60d | 327d | 123d | Etapa de preconstrucción [219250%] | 2,220,612,933 | 3,702,100,940 | 5.4.3.1 | m3 |
| 182 | 5.4.3.2 | Acero de refuerzo (fy = 420 mpa) | 125d | 2021-11-24 | 2022-03-01 | 201SS+13d | 2021-11-24 | 2022-01-05 | 50d | 327d | 0d | Etapa de preconstrucción [83388%] | 293,081,073 | 468,858,459 | 5.4.3.2 | kg |
| 183 | 5.4.3.3 | Acero de preesfuerzo (fpu = 1860 mpa) | 125d | 2021-12-01 | 2022-03-09 | 182SS+10d | 2021-11-24 | 2022-01-05 | 50d | 353d | 26d | Etapa de preconstrucción [86636%] | 1,169,383,146 | 1,149,921,721 | 5.4.3.3 | kg |
| 184 | 5.4.4 | **LOSA INFERIOR "VIGAS PUNTALES"** | 115d | 2022-05-20 | 2022-08-13 |  | 2022-04-13 | 2022-07-25 | 135d | 0d |  |  | 12,371,249,606 | 21,892,439,752 | 5.4.4 |  |
| 185 | 5.4.4.1 | Concreto clase c (incluye encofrado) | 101d | 2022-05-31 | 2022-08-13 | 186SS+14d | 2022-05-04 | 2022-07-25 | 110d | 0d |  | Etapa de preconstrucción [892838%] | 2,979,646,263 | 12,896,235,568 | 5.4.4.1 | m3 |
| 186 | 5.4.4.2 | Acero de refuerzo (fy = 420 mpa) | 101d | 2022-05-20 | 2022-08-03 | 191SS+25d, 203 | 2022-04-13 | 2022-05-30 | 60d | 0d |  | Etapa de preconstrucción [161258%] | 1,669,442,359 | 1,274,043,200 | 5.4.4.2 | kg |
| 187 | 5.4.5 | **CABEZALES** | 57d | 2021-11-21 | 2022-01-07 |  | 2021-09-11 | 2021-11-09 | 80d | 340d |  |  | 683,565,917 | 224,188,696 | 5.4.5 |  |
| 188 | 5.4.5.1 | Concreto clase c (incluye encofrado) | 15d | 2021-12-22 | 2022-01-07 | 189FS+2d | 2021-10-07 | 2021-11-09 | 45d | 340d | 13d | Etapa de preconstrucción [2953%] | 418,438,694 | 29,526,924 | 5.4.5.1 | M3 |
| 189 | 5.4.5.2 | Acero de refuerzo (fy = 420 mpa) | 40d | 2021-11-21 | 2021-12-21 | 1SS+69d | 2021-09-11 | 2021-10-14 | 45d | 340d | 0d | Etapa de preconstrucción [8257%] | 153,032,875 | 82,567,424 | 5.4.5.2 | KG |
| 190 | 5.4.6 | **VIGA DE AMARRE CENTRAL** | 115d | 2022-04-05 | 2022-07-02 |  | 2021-08-02 | 2022-07-28 | 477d | 0d |  |  | 1,266,859,141 | 701,348,057 | 5.4.6 |  |
| 191 | 5.4.3.1 MC | Concreto clase A | 83d | 2022-05-02 | 2022-07-02 | 192SS+5d | 2021-08-27 | 2021-10-22 | 75d | 0d |  |  | 170,444,445 | 180,551,398 | MC | m3 |
| 192 | 5.4.6.2 | Acero de refuerzo (fy = 420 mpa) | 81d | 2022-04-28 | 2022-06-27 | 193SS+7d | 2021-08-27 | 2021-09-30 | 45d | 0d |  | Etapa de preconstrucción [3296%] | 81,071,447 | 139,427,840 | 5.4.6.2 | kg |
| 193 | 5.4.6.3 | Anclaje epoxico (30cm - barra #4) | 35d | 2022-04-23 | 2022-05-19 | 196SS+20d | 2021-08-27 | 2021-09-30 | 45d | 0d |  | Etapa de preconstrucción [2331%] | 4,303,008 | 30,694,790 | 5.4.6.3 |  |
| 194 | 5.4.6.4 NP | Anclajes No. 5 hasta 0,50m | 35d | 2022-04-13 | 2022-05-11 | 196SS+10d, 177 | 2021-08-02 | 2021-09-15 | 60d | 291d | 0d |  | 299,068,224 |  |  |  |
| 195 | 5.4.6.5 NP | Concreto de ensanchamiento de estructuras segunda etapa | 35d | 2022-04-23 | 2022-05-19 | 194SS+10d |  |  |  | 291d |  |  | 250,342,283 |  |  | m2 |
| 196 | 5.4.6.6 NP | Tratamiento de superficie para unión de concreto de segunda etapa | 50d | 2022-04-05 | 2022-05-15 | 163FS+2d, 175SS-2d |  |  |  | 0d |  |  | 110,955,705 |  |  | m2 |

| ID | WBS | Task | Type | Duration | Start | Finish | Predecessors | Baseline start | Baseline finish | Baseline duration | Total slack | Free slack | Resources | Cost | Baseline cost | Text3 | Un |
| --- | --- | --- | --- | --- | --- | --- | --- | --- | --- | --- | --- | --- | --- | --- | --- | --- | --- |
| 197 | 5.4.8 | **BARRERA TIPO NEW YERSEY** |  | 33d | 2022-06-30 | 2022-07-24 |  | 2022-06-10 | 2022-07-05 | 33d | 201d |  |  | 185,790,732 | 185,790,732 | 5.4.8 |  |
| 198 | 5.4.8.1 | Concreto resistensia a la comresion 250kg/cm2 |  | 30d | 2022-07-02 | 2022-07-24 | 199SS+3d | 2022-06-13 | 2022-07-05 | 30d | 201d | 11d | Etapa de preconstrucción [5983%] | 57,868,668 | 57,868,668 | 5.4.8.1 | M3 |
| 199 | 5.4.8.2 | Acero de refuerzo (fy = 420 mpa) |  | 30d | 2022-06-30 | 2022-07-22 | 185FF-30d | 2022-06-10 | 2022-07-02 | 30d | 201d | 0d | Etapa de preconstrucción [3504%] | 35,026,698 | 35,026,698 | 5.4.8.2 | KG |
| 200 | 5.4.9 | **APOYOS Y SELLOS PARA JUNTAS** |  | 186d | 2021-11-14 | 2022-04-06 |  | 2021-11-10 | 2022-07-28 | 342d | 266d |  |  | 4,267,430,440 | 3,413,944,352 | 5.4.9 |  |
| 201 | 5.4.9.1 | Apoyos elastoméricos 700x700x70 |  | 186d | 2021-11-14 | 2022-04-06 | 1SS+60d | 2021-11-10 | 2022-01-20 | 90d | 266d | 0d | Etapa de preconstrucción [44316%] | 2,560,458,264 | 1,706,972,176 | 5.4.9.1 | UN |
| 202 | 5.4.10 | **VIGAS PUNTALES METALICAS** |  | 87d | 2022-02-11 | 2022-04-19 |  | 2021-12-09 | 2022-02-26 | 100d | 42d |  |  | 1,963,282,731 | 2,073,483,194 | 5.4.10 |  |
| 203 | 5.4.10.1 | Vigas puntales metálicas - acero estructural a-500 |  | 87d | 2022-02-11 | 2022-04-19 | 177 | 2021-12-09 | 2022-02-26 | 100d | 42d |  | Etapa de preconstrucción [132559%] | 926,541,134 | 1,036,741,597 | 5.4.10.1 | KG |
| 204 | 5.4.11 | **LOSA DE APROXIMACIÓN** |  | 63d | 2022-05-09 | 2022-06-24 |  | 2022-02-04 | 2022-03-06 | 40d | 241d |  |  | 6,012,230,186 | 5,351,337,457 | 5.4.11 |  |
| 205 | 5.4.3.1 MC | CONCRETO CLASE A |  | 23d | 2022-06-08 | 2022-06-24 | 207FS-15d |  |  |  | 241d | 51d |  | 1,880,626,187 |  |  | m3 |
| 206 | 5.5.1.2 MC | CONCRETO CLASE F |  | 20d | 2022-05-09 | 2022-05-24 | 201FS+16d, 166 |  |  |  | 241d | 0d |  | 41,851,628 |  |  | m3 |
| 207 | 5.5.1.3 MC | Acero de refuerzo (fy = 420 mpa) |  | 35d | 2022-05-24 | 2022-06-18 | 208SS, 206 | 2022-02-04 | 2022-03-06 | 40d | 241d | 0d | Etapa de preconstrucción [42908%] | 276,803,905 | 394,798,643 | 5.4.11.2 | KG |
| 208 | 5.4.3.3 MC | Acero de preesfuerzo (fpu = 1860 Mpa) |  | 40d | 2022-05-24 | 2022-06-22 | 163SS+14d, 206 | 2022-02-04 | 2022-02-19 | 20d | 241d | 0d |  | 1,137,279,737 | 852,329,381 | MC | kg |
| 209 | 5.5 | **DRENAJE ESTRUCTURAS** |  | 175d | 2021-12-14 | 2022-04-30 |  | 2022-05-30 | 2022-08-06 | 92d | 316d |  |  | 417,127,077 | 184,681,668 | 5.5 |  |
| 210 | 5.5.1 | **TANQUE DE BOMBEO** |  | 70d | 2021-12-14 | 2022-02-09 |  | 2022-05-30 | 2022-08-06 | 92d | 359d |  |  | 302,173,751 | 93,941,892 | 5.5.1 |  |
| 211 | 5.5.1.1 | Concreto clase c (incluye encofrado) |  | 40d | 2022-01-10 | 2022-02-09 | 213SS+20d, 212SS+20d | 2022-07-14 | 2022-08-06 | 32d | 359d | 0d | Etapa de preconstrucción [3937%] | 188,227,110 | 38,553,727 | 5.5.1.1 | M3 |
| 212 | 5.5.1.2 | Concreto clase F |  | 10d | 2021-12-14 | 2021-12-21 | 1SS+100d | 2022-05-30 | 2022-06-01 | 2d | 359d | 0d | Etapa de preconstrucción [70%] | 2,925,415 | 699,860 | 5.5.1.2 | M3 |
| 213 | 5.5.1.3 | Acero de refuerzo (fy = 420 mpa) |  | 30d | 2021-12-21 | 2022-01-17 | 212 | 2022-06-29 | 2022-07-21 | 30d | 359d | 0d | Etapa de preconstrucción [772%] | 64,050,280 | 7,717,359 | 5.5.1.3 | KG |
| 214 | 5.5.2 | **CANAL DE DRENAJE** |  | 105d | 2022-02-09 | 2022-04-30 |  | 2022-05-30 | 2022-07-04 | 47d | 316d |  |  | 53,392,770 | 29,179,220 | 5.5.2 |  |
| 215 | 5.5.2.1 | Concreto clase c (incluye encofrado) |  | 32d | 2022-04-04 | 2022-04-30 | 241SS, 217FF+10d | 2022-06-10 | 2022-07-04 | 32d | 316d | 126d | Etapa de preconstrucción [2812%] | 28,120,880 | 11,332,715 | 5.5.2.1 | M3 |
| 216 | 5.5.2.2 | Concreto clase F |  | 10d | 2022-02-09 | 2022-02-16 | 211 | 2022-05-30 | 2022-06-01 | 2d | 359d | 0d | Etapa de preconstrucción [140%] | 1,399,720 | 1,399,720 | 5.5.2.2 | M3 |
| 217 | 5.5.2.3 | Acero de refuerzo (fy = 420 mpa) |  | 32d | 2022-02-23 | 2022-03-19 | 216SS+20d | 2022-06-10 | 2022-07-04 | 32d | 359d | 43d | Etapa de preconstrucción [989.9%] | 9,282,560 | 1,857,175 | 5.5.2.3 | KG |
| 218 | 5.6 | **OTRAS PARTIDAS COMPLEMENTARIAS** |  | 35d | 2022-07-07 | 2022-08-02 |  | 2022-02-13 | 2022-07-28 | 220d | 190d |  |  | 1,531,018,540 | 674,144,790 | 5.6 |  |
| 219 | 5.6.1 | Prueba de carga sobre estructura |  | 15d | 2022-07-11 | 2022-07-22 | 154FF+30d, 181FF+30d | 2022-02-13 | 2022-02-24 | 15d | 204d | 14d | Etapa de preconstrucción [6989%] | 69,892,583 | 69,892,583 | 5.6.1 | UN |
| 220 | 5.6.2 | Impermeabilización sistema voltex o similar (losa inf) |  | 30d | 2022-07-07 | 2022-07-29 | 185SS+50d | 2022-07-28 | 2022-07-28 | 0d | 190d | 0d | Etapa de preconstrucción | 856,873,750 |  | 5.6.2 | M2 |
| 221 | 5.6.3 | impermeabilización sistema sikaflex pro 3 wf o similar (10mm*10mm) |  | 30d | 2022-07-07 | 2022-07-29 | 220SS | 2022-05-16 | 2022-05-26 | 15d | 190d | 0d | Etapa de preconstrucción [6095%] | 63,010,788 | 63,010,788 | 5.6.3 | ML |
| 222 | 5.6.4 | impermeabilización sistema voltex o similar (losa sup) |  | 30d | 2022-07-10 | 2022-08-02 | 221SS+5d | 2022-05-19 | 2022-05-30 | 15d | 190d | 0d | Etapa de preconstrucción [20171%] | 204,169,024 | 204,169,024 | 5.6.4 | M2 |
| 223 | 5.7 | Fin estructuras y elementos de contención | milestone | 0d | 2022-08-02 | 2022-08-02 | 222, 198, 215, 219, 211SS, 205 | 2022-07-28 | 2022-07-28 | 0d | 190d |  |  |  |  | Hito |  |

| ID | WBS | Task | Type | Duration | Start | Finish | Predecessors | Baseline start | Baseline finish | Baseline duration | Total slack | Free slack | Resources | Cost | Baseline cost | Text3 | Un |
| --- | --- | --- | --- | --- | --- | --- | --- | --- | --- | --- | --- | --- | --- | --- | --- | --- | --- |
| 224 | 6 | **DRENAJE** |  | 150d | 2022-02-18 | 2022-06-12 |  | 2021-08-02 | 2022-06-03 | 402d | 258d |  |  | -47,908,768,060 | 11,839,789,494 |  |  |
| 225 | 6.1 | **MOVIMIENTO DE TIERRAS** |  | 130d | 2022-02-18 | 2022-05-28 |  | 2021-08-02 | 2022-05-12 | 372d | 258d |  |  | 1,614,203,384 | 1,840,253,742 | 6.1 |  |
| 226 | 6.1.1 | Excavación sin clasificar de canales y zanjas, retiro y disposición |  | 60d | 2022-02-18 | 2022-04-04 | 163FF | 2022-03-18 | 2022-05-04 | 60d | 258d | 0d | Etapa de preconstrucción [7325%] | 89,033,125 | 48,467,184 | 6.1.1 | M3 |
| 227 | 6.1.2 | Relleno gravilla y arena |  | 60d | 2022-04-04 | 2022-05-21 | 226, 256SS | 2021-08-02 | 2021-09-15 | 60d | 258d | 0d | Etapa de preconstrucción [2716%] | 278,635,231 | 51,575,184 | 6.1.2 | M3 |
| 228 | 6.1.3 | Relleno localizado con suelo seleccionado b200 |  | 60d | 2022-04-04 | 2022-05-21 | 227SS | 2021-10-08 | 2021-11-22 | 60d | 288d | 0d | Etapa de preconstrucción [18007%] | 17,965,992 | 180,068,238 | 6.1.3 | M3 |
| 229 | 6.1.4 | Relleno con recebo común compactado |  | 60d | 2022-02-25 | 2022-04-11 | 226SS+10d | 2022-03-25 | 2022-05-12 | 60d | 278d | 0d | Etapa de preconstrucción [2252.2%] | 17,926,500 | 17,926,500 | 6.1.4 | M3 |
| 230 | 6.1.5 | Protección con concreto simple f'c=21 mpa para conducciones |  | 60d | 2022-04-11 | 2022-05-28 | 229 | 2021-08-09 | 2021-09-22 | 60d | 278d | 0d | Etapa de preconstrucción [36825%] | 36,674,105 | 368,248,205 | 6.1.5 | M3 |
| 231 | 6.2 | **TUBERÍAS Y CANALES PREFRABICADOS** |  | 90d | 2022-04-04 | 2022-06-12 |  | 2021-08-02 | 2022-06-03 | 402d | 258d |  |  | 1,442,779,938 | 1,694,274,963 | 6.2 |  |
| 232 | 6.2.1 | **TUBERÍA PVC CORRUGADA** |  | 0d | 2022-05-28 | 2022-05-28 |  | 2022-03-11 | 2022-05-12 | 80d | 278d |  |  | 28,230,900 | 21,122,400 | 6.2.1 |  |
| 233 | 6.2.1.1 | Tubería pvc corrugado 315 mm | milestone | 0d | 2022-05-28 | 2022-05-28 | 264 | 2022-04-19 | 2022-04-19 | 0d | 278d | 0d | Etapa de preconstrucción | 17,669,700 |  | 6.2.1.1 |  |
| 234 | 6.2.2 | **TUBERÍA PEAD** |  | 90d | 2022-04-04 | 2022-06-12 |  | 2021-08-02 | 2022-04-19 | 342d | 258d |  |  | 223,349,451 | 102,009,910 | 6.2.2 |  |
| 235 | 6.2.2.1 | Tuberia pead pe 100 6 atm dn=400mm | milestone | 0d | 2022-05-28 | 2022-05-28 | 264, 233 | 2022-04-19 | 2022-04-19 | 0d | 278d | 20d | Etapa de preconstrucción | 8,917,956 |  | 6.2.2.1 |  |
| 236 | 6.2.2.2 NP | Suministro e instalación Tubería PEAD PE 100 6 ATM DN=200mm |  | 90d | 2022-04-04 | 2022-06-12 | 227SS | 2021-08-02 | 2021-10-07 | 90d | 258d | 0d |  | 163,426,540 | 47,178,864 | NP |  |
| 237 | 6.2.3 | **CANALES PREFABRICADOS HORMIGÓN POLÍMERO** |  | 0d | 2022-06-12 | 2022-06-12 |  | 2022-04-02 | 2022-06-03 | 80d | 258d |  |  | 626,441,266 | 1,006,384,332 | 6.2.3 |  |
| 238 | 6.2.3.1 | Canal prefabricado (h=300 mm) | milestone | 0d | 2022-06-12 | 2022-06-12 | 264, 235, 236 | 2022-04-19 | 2022-04-19 | 0d | 258d |  | Etapa de preconstrucción | 123,249,100 |  | 6.2.3.1 |  |
| 239 | 6.3 | **POZOS, ARQUETAS Y SUMIDEROS** |  | 30d | 2022-04-04 | 2022-04-28 |  | 2021-08-02 | 2022-04-23 | 347d | 316d |  |  | 2,146,378,179 | 385,871,058 | 6.3 |  |
| 240 | 6.3.1 | **CAJAS** |  | 20d | 2022-04-04 | 2022-04-21 |  | 2022-03-15 | 2022-04-23 | 50d | 316d |  |  | 762,660,870 | 257,247,372 | 6.3.1 |  |
| 241 | 6.3.1.2 | Caja para drenaje |  | 20d | 2022-04-04 | 2022-04-21 | 227SS | 2022-03-15 | 2022-04-23 | 50d | 316d | 0d | Etapa de preconstrucción [1893%] | 75,701,448 | 18,925,362 | 6.3.1.2 | un |
| 242 | 6.3.1.3 | Caja para drenaje subterráneo |  | 20d | 2022-04-04 | 2022-04-21 | 241SS | 2022-04-19 | 2022-04-19 | 0d | 318d | 0d | Etapa de preconstrucción | 558,335,736 |  | 6.3.1.3 | un |
| 243 | 6.3.2 | **POZO DE BOMBEO** |  | 30d | 2022-04-04 | 2022-04-28 |  | 2021-08-02 | 2022-04-19 | 342d | 318d |  |  | 1,255,093,623 |  | 6.3.2 |  |
| 244 | 6.3.2.1 | Tapa servoasistida 1,00 m x 1,50 m para pozo bombeo |  | 30d | 2022-04-04 | 2022-04-28 | 242SS | 2022-04-19 | 2022-04-19 | 0d | 318d | 0d | Etapa de preconstrucción | 702,606,775 |  | 6.3.2.1 | UN |
| 245 | 6.3.2.2 | Tapa servoasistida 0,60 m x 0,80 m para pozo bombeo |  | 30d | 2022-04-04 | 2022-04-28 | 244SS | 2022-04-19 | 2022-04-19 | 0d | 318d | 40d | Etapa de preconstrucción | 552,486,848 |  | 6.3.2.2 | UN |
| 246 | 6.4 | **ELEMENTOS AUXILIARES DE DRENAJE** |  | 95d | 2022-02-25 | 2022-05-10 |  | 2021-08-02 | 2022-04-19 | 342d | 303d |  |  | -56,492,489,822 | 4,539,029,470 | 6.4 |  |
| 247 | 6.4.1 | **CUNETAS REVESTIDAS DE CONCRETO** |  | 45d | 2022-04-04 | 2022-05-10 |  | 2022-03-15 | 2022-04-19 | 45d | 303d |  |  | 1,131,823,238 | 1,123,541,639 | 6.4.1 |  |
| 248 | 5.5.1.1 MC | CUNETA CONCRETO REFORZADO TIPO II (CTO Clase C) |  | 45d | 2022-04-04 | 2022-05-10 | 228SS | 2022-03-15 | 2022-04-19 | 45d | 303d | 0d |  | 53,823,364 | 46,090,122 | NP | m3 |
| 249 | 5.5.1.1 MC | CUNETA CONCRETO REFORZADO TIPO III (CTO Clase C) |  | 45d | 2022-04-04 | 2022-05-10 | 248SS | 2022-03-15 | 2022-04-19 | 45d | 303d | 0d |  | 254,508,024 | 253,959,667 | NP | m3 |
| 250 | 5.5.1.1 MC | CUNETA CONCRETO REFORZADO TIPO IV (CTO Clase C) |  | 45d | 2022-04-04 | 2022-05-10 | 249SS | 2022-03-15 | 2022-04-19 | 45d | 303d | 0d |  | 110,093,245 | 110,093,245 | NP | m3 |
| 251 | 5.5.1.1 MC | CUNETA CONCRETO REFORZADO TIPO V (CTO Clase C) |  | 45d | 2022-04-04 | 2022-05-10 | 250SS | 2022-03-15 | 2022-04-19 | 45d | 303d | 0d |  | 130,438,702 | 130,438,702 | NP | m3 |
| 252 | 5.5.1.1 MC | CUNETA CONCRETO REFORZADO TIPO VI (CTO Clase C) |  | 45d | 2022-04-04 | 2022-05-10 | 251SS | 2022-03-15 | 2022-04-19 | 45d | 303d | 0d |  | 21,189,083 | 21,189,083 | NP | m3 |

| ID | WBS | Task | Type | Duration | Start | Finish | Predecessors | Baseline start | Baseline finish | Baseline duration | Total slack | Free slack | Resources | Cost | Baseline cost | Text3 | Un |
| --- | --- | --- | --- | --- | --- | --- | --- | --- | --- | --- | --- | --- | --- | --- | --- | --- | --- |
| 253 | 6.4.2 | **SUBDRENES CON GEOTEXTIL Y MATERIAL GRANULAR** |  | 90d | 2022-02-25 | 2022-05-06 |  | 2022-03-15 | 2022-04-19 | 45d | 308d |  |  | -60,630,242,475 | 413,592,916 | 6.4.2 |  |
| 254 | 6.4.2.1 | Zanja drenante de 0,60 m x 1,50 m (tipo 1) |  | 40d | 2022-04-04 | 2022-05-06 | 252SS | 2022-04-19 | 2022-04-19 | 0d | 308d | 0d | Etapa de preconstrucción | -9,984,312,420 |  | 6.4.2.1 |  |
| 255 | 6.4.2.2 | Zanja drenante de 0,60 m x 1,50 m (tipo 2) |  | 40d | 2022-04-04 | 2022-05-06 | 254SS | 2022-04-19 | 2022-04-19 | 0d | 308d |  | Etapa de preconstrucción | -50,874,867,776 |  | 6.4.2.2 |  |
| 256 | 2.4.1.2 MC | Geotextil no tejido 2000 para sub drenaje |  | 40d | 2022-02-25 | 2022-03-27 | 229SS | 2022-03-15 | 2022-04-13 | 40d | 308d | 50d |  | 22,141,263 | 22,144,682 | MC | m2 |
| 257 | 6.4.3 | **ELEMENTOS PARA IMPULSIÓN** |  | 20d | 2022-03-18 | 2022-04-02 |  | 2022-01-21 | 2022-04-19 | 115d | 310d |  |  | 64,849,546 | 64,849,546 | 6.4.3 |  |
| 258 | 6.4.3.2 | Cuadro eléctrico para mando y protección bombeo |  | 20d | 2022-03-18 | 2022-04-02 | 307SS | 2022-01-21 | 2022-02-05 | 20d | 310d | 0d | Etapa de preconstrucción [1965.7%] | 23,006,889 | 23,006,889 | 6.4.3.2 | UN |
| 259 | 6.4.3.3 | Protección diferencial para bombas |  | 20d | 2022-03-18 | 2022-04-02 | 258SS | 2022-01-21 | 2022-02-05 | 20d | 310d | 0d | Etapa de preconstrucción [661%] | 6,612,744 | 6,612,744 | 6.4.3.3 | UN |
| 260 | 6.4.3.4 | Regulador de nivel para densidad |  | 20d | 2022-03-18 | 2022-04-02 | 259SS | 2022-01-21 | 2022-02-05 | 20d | 350d | 72d | Etapa de preconstrucción [57%] | 570,116 | 570,116 | 6.4.3.4 | UN |
| 261 | 6.4.3.5 | Sensor capacitivo sumergible de nivel |  | 20d | 2022-03-18 | 2022-04-02 | 259SS | 2022-01-21 | 2022-02-05 | 20d | 350d | 72d | Etapa de preconstrucción [224%] | 2,235,024 | 2,235,024 | 6.4.3.5 | UN |
| 262 | 6.4.4 | **ACCESORIOS CÁRCAMO DE BOMBEO** |  | 60d | 2022-03-18 | 2022-05-04 |  | 2021-08-02 | 2022-04-19 | 342d | 310d |  |  | 1,428,070,046 | 1,410,922,186 |  |  |
| 263 | 6.4.3.9 NP | Suministro e Instalación Bomba sumergible KRTK 250-403 1450RPM ɸ=330MM |  | 60d | 2022-03-18 | 2022-05-04 | 259SS | 2021-08-02 | 2021-09-15 | 60d | 310d | 32d |  | 722,608,953 | 349,426,242 | NP | un |
| 264 | 6.5 | Fin drenaje | milestone | 0d | 2022-05-28 | 2022-05-28 | 228, 230, 258, 260, 261, 263, 245 | 2022-04-19 | 2022-04-19 | 0d | 278d | 0d |  |  |  | Hito |  |
| 265 | 7 | **SEÑALIZACIÓN Y SEGURIDAD** |  | 305d | 2022-05-05 | 2022-12-16 |  | 2022-04-07 | 2022-05-28 | 65d | 5d |  |  | 1,029,037,948 | 1,027,131,170 |  |  |
| 266 | 7.1 | **SEÑALIZACIÓN HORIZONTAL CARRETERAS** |  | 295d | 2022-05-05 | 2022-12-09 |  | 2022-04-07 | 2022-04-21 | 15d | 5d |  |  | 89,384,214 | 89,384,214 | 7.1 |  |
| 267 | 7.1.1 | **LÍNEAS DE DEMARCACIÓN Y MARCAS VIALES** |  | 295d | 2022-05-05 | 2022-12-09 |  | 2022-04-07 | 2022-04-21 | 15d | 5d |  |  | 53,450,288 | 53,450,288 | 7.1.1 |  |
| 268 | 7.1.1.1 | M. vial permanente en frío con plástico de 2 componentes 12cm |  | 295d | 2022-05-05 | 2022-12-09 | 154SS | 2022-04-07 | 2022-04-21 | 15d | 5d | 0d | Etapa de preconstrucción [1630%] | 16,301,016 | 16,301,016 | 7.1.1.1 | ML |
| 269 | 7.1.1.2 | M. vial permanente plástica en frío 2 componentes |  | 295d | 2022-05-05 | 2022-12-09 | 268SS | 2022-04-07 | 2022-04-21 | 15d | 5d | 0d | Etapa de preconstrucción [1042%] | 10,424,128 | 10,424,128 | 7.1.1.2 | M2 |
| 270 | 7.1.2 | **TACHAS REFLECTIVAS** |  | 295d | 2022-05-05 | 2022-12-09 |  | 2022-04-07 | 2022-04-21 | 15d | 5d |  |  | 6,139,188 | 6,139,188 | 7.1.2 |  |
| 271 | 7.1.2.1 | Tachas reflectivas |  | 295d | 2022-05-05 | 2022-12-09 | 269SS | 2022-04-07 | 2022-04-21 | 15d | 5d | 0d | Etapa de preconstrucción [307%] | 3,069,594 | 3,069,594 | 7.1.2.1 | UN |
| 272 | 7.2 | **SEÑALIZACIÓN VERTICAL** |  | 220d | 2022-07-07 | 2022-12-16 |  | 2022-04-11 | 2022-04-21 | 10d | 5d |  |  | 19,196,884 | 19,196,884 | 7.2 |  |
| 273 | 7.2.1 | Señal reglamentaria circular 900 mm de diámetro |  | 220d | 2022-07-07 | 2022-12-16 | 271SS+85d | 2022-04-11 | 2022-04-21 | 10d | 5d | 0d | Etapa de preconstrucción [275%] | 2,752,280 | 2,752,280 | 7.2.1 | UN |
| 274 | 7.2.2 | Señal preventiva cuadrada 900 mm de lado |  | 220d | 2022-07-07 | 2022-12-16 | 273SS | 2022-04-11 | 2022-04-21 | 10d | 5d | 0d | Etapa de preconstrucción [631%] | 6,309,564 | 6,309,564 | 7.2.2 | UN |
| 275 | 7.2.3 | Delineador de obstáculos |  | 220d | 2022-07-07 | 2022-12-16 | 274SS | 2022-04-11 | 2022-04-21 | 10d | 5d | 0d | Etapa de preconstrucción [54%] | 536,598 | 536,598 | 7.2.3 | UN |
| 276 | 7.3 | **ELEMENTOS AUXILIARES** |  | 50d | 2022-05-23 | 2022-06-29 |  | 2022-04-11 | 2022-04-25 | 15d | 235d |  |  | 327,825,072 | 327,825,072 | 7.3 |  |
| 277 | 7.3.1 | Bandas sonoras |  | 50d | 2022-05-23 | 2022-06-29 | 275SS-60d | 2022-04-11 | 2022-04-25 | 15d | 235d | 0d | Etapa de preconstrucción [134%] | 1,336,755 | 1,336,755 | 7.3.1 | ML |
| 278 | 7.3.2 | Delineador tubular |  | 50d | 2022-05-23 | 2022-06-29 | 277SS | 2022-04-11 | 2022-04-25 | 15d | 235d | 0d | Etapa de preconstrucción [321%] | 3,207,580 | 3,207,580 | 7.3.2 | UN |
| 279 | 7.3.3 | Barrera new jersey |  | 50d | 2022-05-23 | 2022-06-29 | 278SS | 2022-04-11 | 2022-04-25 | 15d | 235d | 0d | Etapa de preconstrucción [2706%] | 27,057,750 | 27,057,750 | 7.3.3 | UN |
| 280 | 7.3.4 | Jalonamiento perimetral temporal |  | 50d | 2022-05-23 | 2022-06-29 | 279SS | 2022-04-11 | 2022-04-25 | 15d | 235d | 0d | Etapa de preconstrucción [147%] | 1,473,360 | 1,473,360 | 7.3.4 | ML |
| 281 | 7.3.5 | Elementos varios de señalización: carteles limitación de altura, banderola, barrera tipo stopper |  | 50d | 2022-05-23 | 2022-06-29 | 280SS | 2022-04-11 | 2022-04-12 | 1d | 235d | 0d | Etapa de preconstrucción [129%] | 1,290,835 | 1,290,835 | 7.3.5 | UN |
| 282 | 7.3.6 | Baliza autónoma de área fuera de servicio i/cono o barricada |  | 50d | 2022-05-23 | 2022-06-29 | 281SS | 2022-04-11 | 2022-04-25 | 15d | 235d | 0d | Etapa de preconstrucción [12955%] | 129,546,256 | 129,546,256 | 7.3.6 | UN |

| ID | WBS | Task | Type | Duration | Start | Finish | Predecessors | Baseline start | Baseline finish | Baseline duration | Total slack | Free slack | Resources | Cost | Baseline cost | Text3 | Un |
| --- | --- | --- | --- | --- | --- | --- | --- | --- | --- | --- | --- | --- | --- | --- | --- | --- | --- |
| 283 | 7.4 | **SEÑALIZACIÓN HORIZONTAL ÁREA DE MOVIMIENTOS** |  | 38d | 2022-05-23 | 2022-06-20 |  | 2022-04-11 | 2022-05-28 | 60d | 247d |  |  | 260,186,301 | 258,279,523 | 7.4 |  |
| 284 | 7.4.1 | Pintura reflexiva amarilla. aplicación automática faa p - 620 |  | 38d | 2022-05-23 | 2022-06-20 | 282SS | 2022-04-11 | 2022-05-20 | 50d | 247d | 0d | Etapa de preconstrucción [7407%] | 74,074,374 | 32,588,309 | 7.4.1 | M2 |
| 285 | 7.4.2 | Pintura reflexiva amarilla. aplicación manual faa p - 620 |  | 38d | 2022-05-23 | 2022-06-20 | 284SS | 2022-04-11 | 2022-05-28 | 60d | 247d | 0d | Etapa de preconstrucción [1354%] | 13,539,526 | 55,816,933 | 7.4.2 | M2 |
| 286 | 7.4.3 | Pintura no reflexiva negra. aplicación manual faa p - 620 |  | 38d | 2022-05-23 | 2022-06-20 | 285SS | 2022-04-11 | 2022-05-02 | 25d | 247d | 0d | Etapa de preconstrucción [807%] | 8,066,058 | 11,870,477 | 7.4.3 | M2 |
| 287 | 7.4.4 | Pintura reflexiva blanca. aplicación manual faa p - 620 |  | 38d | 2022-05-23 | 2022-06-20 | 286SS | 2022-04-11 | 2022-04-28 | 20d | 247d | 0d | Etapa de preconstrucción [97%] | 974,996 | 443,180 | 7.4.4 | M2 |
| 288 | 7.4.5 | Pintura reflexiva roja aplicación manual faa p - 620 |  | 38d | 2022-05-23 | 2022-06-20 | 287SS | 2022-04-11 | 2022-05-06 | 30d | 247d | 0d | Etapa de preconstrucción [625%] | 6,251,784 | 2,349,155 | 7.4.5 | M2 |
| 289 | 7.4.6 | Limpieza de superficie |  | 38d | 2022-05-23 | 2022-06-20 | 288SS | 2022-04-11 | 2022-05-28 | 60d | 247d | 0d | Etapa de preconstrucción [2784%] | 27,838,080 | 25,769,986 | 7.4.6 | M2 |
| 290 | 7.4.7 | Borrado de señalización horizontal |  | 30d | 2022-05-23 | 2022-06-14 | 289SS | 2022-04-11 | 2022-05-06 | 30d | 255d | 0d | Etapa de preconstrucción [29%] | 294,750 | 294,750 | 7.4.7 | M2 |
| 291 | 7.4.8 | Replanteo señalización horizontal existente |  | 20d | 2022-05-23 | 2022-06-07 | 290SS | 2022-04-11 | 2022-04-25 | 15d | 265d | 30d | Etapa de preconstrucción [1%] | 6,972 | 6,972 | 7.4.8 | UN |
| 292 | 7.5 | Fin Señalización y Seguridad | milestone | 0d | 2022-06-29 | 2022-06-29 | 285, 286, 287, 288, 289, 290, 291, 277, 278, 279, 280, 281, 282 | 2022-05-28 | 2022-05-28 | 0d | 235d |  |  |  |  | Hito |  |
| 293 | 8 | **AYUDAS VISUALES** |  | 158d | 2022-03-18 | 2022-07-16 |  | 2021-08-02 | 2022-05-28 | 394d | 212d |  |  | 19,486,208,920 | 24,960,070,209 |  |  |
| 294 | 8.1 | **EJE DE CALLE DE RODAJE LIMA** |  | 125d | 2022-03-18 | 2022-06-22 |  | 2022-01-21 | 2022-02-24 | 45d | 212d |  |  | 2,836,364,651 | 2,601,432,842 | 8.1 |  |
| 295 | 8.1.1 | Baliza Bidireccional verde verde empotrada recta, FAA L852 C o FAA L 852 D |  | 125d | 2022-03-18 | 2022-06-22 | 154SS-60d | 2022-01-21 | 2022-02-24 | 45d | 212d | 0d | Etapa de preconstrucción [37352%] | 421,297,869 | 416,954,592 | 8.1.1 | UN |
| 296 | 8.1.2 | Baliza Bidireccional verde verde empotrada curva, FAA L852 C o FAA L 852 D |  | 125d | 2022-03-18 | 2022-06-22 | 295SS | 2022-01-21 | 2022-02-24 | 45d | 212d | 0d | Etapa de preconstrucción [5212%] | 186,760,911 | 99,895,371 | 8.1.2 | UN |
| 297 | 8.1.3 | Transformador de aislamiento 25W/65W, 6,6/6,6A, W/ Earthing |  | 125d | 2022-03-18 | 2022-06-22 | 296SS | 2022-01-21 | 2022-02-24 | 45d | 212d | 0d | Etapa de preconstrucción [6551%] | 91,720,440 | 77,962,374 | 8.1.3 | UN |
| 298 | 8.1.4 | Juego de conectores Primarios - 5KV/25A 8SQmm |  | 125d | 2022-03-18 | 2022-06-22 | 297SS | 2022-01-21 | 2022-02-24 | 45d | 212d | 0d | Etapa de preconstrucción [1024%] | 14,331,380 | 12,181,673 | 8.1.4 | UN |
| 299 | 8.1.5 | Juego de conectores secundarios - FAA L823 12 X 2 Core |  | 125d | 2022-03-18 | 2022-06-22 | 298SS | 2022-01-21 | 2022-02-24 | 45d | 212d | 0d | Etapa de preconstrucción [2691%] | 18,835,460 | 16,010,141 | 8.1.5 | UN |
| 300 | 8.1.6 | Base poco profunda - 8", FAA L- 868 |  | 125d | 2022-03-18 | 2022-06-22 | 299SS | 2022-01-21 | 2022-02-24 | 45d | 212d | 0d | Etapa de preconstrucción [13615%] | 163,933,270 | 134,758,705 | 8.1.6 | UN |
| 301 | 8.1.7 | Dispositivos de Control Doble Canal 2 (Para Baliza) |  | 125d | 2022-03-18 | 2022-06-22 | 300SS | 2022-01-21 | 2022-02-24 | 45d | 212d | 0d | Etapa de preconstrucción [45626%] | 638,768,900 | 542,953,565 | 8.1.7 | UN |
| 302 | 8.2 | **BARRA DE PARADA (STOP WAYS)** |  | 125d | 2022-03-18 | 2022-06-22 |  | 2022-01-21 | 2022-02-24 | 45d | 212d |  |  | 1,464,488,648 | 1,474,970,984 | 8.2 |  |
| 303 | 8.2.1 | Baliza Bidireccional amarillo/verde empotrada recta, FAA L852 C/D/S LED |  | 125d | 2022-03-18 | 2022-06-22 | 301SS | 2022-01-21 | 2022-02-24 | 45d | 212d | 0d | Etapa de preconstrucción [5212%] | 52,119,324 | 52,119,324 | 8.2.1 | UN |
| 304 | 8.2.2 | Baliza Bidireccional verde/verde empotrada recta FAA L852 C/D/S LED |  | 125d | 2022-03-18 | 2022-06-22 | 303SS | 2022-01-21 | 2022-02-24 | 45d | 212d | 0d | Etapa de preconstrucción [4778%] | 52,119,324 | 52,119,324 | 8.2.2 | UN |
| 305 | 8.2.3 | Baliza Bidireccional amarilla/verde empotrada curva FAA L852 C/D/S LED |  | 125d | 2022-03-18 | 2022-06-22 | 304SS |  |  |  | 212d | 0d |  | 8,686,554 |  |  | UN |
| 306 | 8.2.4 | Baliza Bidireccional verde/verde curva, FAA L852 C/D/S LED |  | 125d | 2022-03-18 | 2022-06-22 | 305SS |  |  |  | 212d | 0d |  | 8,686,554 |  |  | UN |
| 307 | 8.2.5 | Transformador de aislamiento 65W, 6,6/6,6A, W/ Earthing |  | 125d | 2022-03-18 | 2022-06-22 | 306SS | 2022-01-21 | 2022-02-24 | 45d | 212d | 0d | Etapa de preconstrucción [2293%] | 7,861,752 | 18,344,088 | 8.2.5 | UN |
| 308 | 8.2.6 | Base poco profunda - 8", FAA 868 |  | 125d | 2022-03-18 | 2022-06-22 | 307SS | 2022-01-21 | 2022-02-24 | 45d | 212d | 0d | Etapa de preconstrucción [4862%] | 20,838,975 | 20,838,975 | 8.2.6 | UN |
| 309 | 8.2.7 | Juego de conectores Primarios - 5KV/25A 8SQmm |  | 125d | 2022-03-18 | 2022-06-22 | 308SS | 2022-01-21 | 2022-02-24 | 45d | 212d | 0d | Etapa de preconstrucción [358%] | 1,535,505 | 1,535,505 | 8.2.7 | UN |
| 310 | 8.2.8 | Juego de conectores secundarios - FAA L823 12 X 2 Core |  | 125d | 2022-03-18 | 2022-06-22 | 309SS | 2022-01-21 | 2022-02-24 | 45d | 212d | 0d | Etapa de preconstrucción [942%] | 2,018,085 | 2,018,085 | 8.2.8 | UN |
| 311 | 8.2.9 | Dispositivos de control canal doble (Para Baliza) |  | 125d | 2022-03-18 | 2022-06-22 | 310SS | 2022-01-21 | 2022-02-24 | 45d | 212d | 0d | Etapa de preconstrucción [15969%] | 127,753,780 | 127,753,780 | 8.2.9 | UN |
| 312 | 8.2.10 | Baliza Unidireccional roja empotrada, FAA L852S LED |  | 125d | 2022-03-18 | 2022-06-22 | 311SS | 2022-01-21 | 2022-02-24 | 45d | 212d | 0d | Etapa de preconstrucción [4422%] | 47,907,652 | 47,907,652 | 8.2.10 | UN |
| 313 | 8.2.11 | Transformador de aislamiento 65W, 6,6/6,6A, W/ Earthing |  | 125d | 2022-03-18 | 2022-06-22 | 312SS | 2022-01-21 | 2022-02-24 | 45d | 212d | 0d | Etapa de preconstrucción [786%] | 8,516,898 | 8,516,898 | 8.2.11 | UN |
| 314 | 8.2.12 | Baliza de protección de pista Elevada RGL, FAA L804 |  | 125d | 2022-03-18 | 2022-06-22 | 313SS | 2022-01-21 | 2022-02-24 | 45d | 212d | 0d | Etapa de preconstrucción [4299%] | 42,994,054 | 42,994,054 | 8.2.12 | UN |
| 315 | 8.2.13 | Transformador de aislamiento - 065W, 6,6/6,6A, W/ Earthing |  | 125d | 2022-03-18 | 2022-06-22 | 314SS | 2022-01-21 | 2022-02-24 | 45d | 212d | 0d | Etapa de preconstrucción [131%] | 1,310,292 | 1,310,292 | 8.2.13 | UN |
| 316 | 8.2.14 | Base poco profunda - 8, FAA 868 |  | 125d | 2022-03-18 | 2022-06-22 | 315SS | 2022-01-21 | 2022-02-24 | 45d | 212d | 0d | Etapa de preconstrucción [1667%] | 18,060,445 | 18,060,445 | 8.2.14 | UN |
| 317 | 8.2.15 | Juego de conectores Primarios - 5KV/25A 8SQmm |  | 125d | 2022-03-18 | 2022-06-22 | 316SS | 2022-01-21 | 2022-02-24 | 45d | 212d | 0d | Etapa de preconstrucción [143%] | 1,535,505 | 1,535,505 | 8.2.15 | UN |
| 318 | 8.2.16 | Juego de conectores secundarios - FAA L823 12 X 2 Core |  | 125d | 2022-03-18 | 2022-06-22 | 317SS | 2022-01-21 | 2022-02-24 | 45d | 212d | 0d | Etapa de preconstrucción [161%] | 2,018,085 | 2,018,085 | 8.2.16 | UN |
| 319 | 8.2.17 | Dispositivos de Control Doble Canal 2 (Para Baliza) |  | 125d | 2022-03-18 | 2022-06-22 | 318SS | 2022-01-21 | 2022-02-24 | 45d | 212d | 0d | Etapa de preconstrucción [913%] | 9,125,270 | 9,125,270 | 8.2.17 | UN |
| 320 | 8.2.18 | Dispositivos de control canal sencillo (Para baliza) |  | 125d | 2022-03-18 | 2022-06-22 | 319SS | 2022-01-21 | 2022-02-24 | 45d | 212d | 0d | Etapa de preconstrucción [4949%] | 53,610,960 | 53,610,960 | 8.2.18 | UN |
| 321 | 8.2.19 | SENSORES DE INSTRUSION A PISTA A1 |  | 125d | 2022-03-18 | 2022-06-22 | 320SS | 2022-01-21 | 2022-02-24 | 45d | 212d | 0d | Etapa de preconstrucción [26030%] | 260,304,142 | 260,304,142 | 8.2.19 | UN |

| ID | WBS | Task | Type | Duration | Start | Finish | Predecessors | Baseline start | Baseline finish | Baseline duration | Total slack | Free slack | Resources | Cost | Baseline cost | Text3 | Un |
| --- | --- | --- | --- | --- | --- | --- | --- | --- | --- | --- | --- | --- | --- | --- | --- | --- | --- |
| 322 | 8.3 | **BARRA DE ESPERA** |  | 45d | 2022-05-23 | 2022-06-25 |  | 2022-01-25 | 2022-02-28 | 45d | 212d |  |  | 194,684,103 | 193,473,252 | 8.3 |  |
| 323 | 8.3.1 | Baliza unidireccional amarillo empotrada FAA L852 C/D/S LED |  | 45d | 2022-05-23 | 2022-06-25 | 321FS-40d | 2022-01-25 | 2022-02-28 | 45d | 212d | 0d | Etapa de preconstrucción [3909%] | 39,089,493 | 39,089,493 | 8.3.1 | UN |
| 324 | 8.3.2 | Transformador de aislamiento 65W, 6,6/6,6A, W/ Earthing |  | 45d | 2022-05-23 | 2022-06-25 | 323SS | 2022-01-25 | 2022-02-28 | 45d | 212d | 0d | Etapa de preconstrucción [590%] | 5,896,314 | 5,896,314 | 8.3.2 | UN |
| 325 | 8.3.3 | Base poco profunda - 8, FAA 868 |  | 45d | 2022-05-23 | 2022-06-25 | 324SS | 2022-01-25 | 2022-02-28 | 45d | 212d | 0d | Etapa de preconstrucción [1250%] | 12,503,385 | 12,503,385 | 8.3.3 | UN |
| 326 | 8.3.4 | Juego de conectores Primarios - 5KV/25A 8SQmm |  | 45d | 2022-05-23 | 2022-06-25 | 325SS | 2022-01-25 | 2022-02-28 | 45d | 212d | 0d | Etapa de preconstrucción [92%] | 921,303 | 921,303 | 8.3.4 | UN |
| 327 | 8.3.5 | Juego de conectores secundarios - FAA L823 12 X 2 Core |  | 45d | 2022-05-23 | 2022-06-25 | 326SS | 2022-01-25 | 2022-02-28 | 45d | 212d | 0d | Etapa de preconstrucción [242%] | 2,421,702 | 1,210,851 | 8.3.5 | UN |
| 328 | 8.3.6 | Dispositivos de control canal sencillo (Para baliza) |  | 45d | 2022-05-23 | 2022-06-25 | 327SS | 2022-01-25 | 2022-02-28 | 45d | 212d | 0d | Etapa de preconstrucción [3712%] | 37,115,280 | 37,115,280 | 8.3.6 | UN |
| 329 | 8.4 | **LETREROS** |  | 60d | 2022-05-23 | 2022-07-06 |  | 2022-03-27 | 2022-05-13 | 60d | 212d |  |  | 896,878,378 | 896,878,378 | 8.4 |  |
| 330 | 8.4.1 | Aviso-Taxiway Guidance Sign(LED Type) - 850x2800 , 24V, FAA L858 |  | 30d | 2022-05-23 | 2022-06-14 | 328SS | 2022-03-27 | 2022-04-21 | 30d | 212d | 0d | Etapa de preconstrucción [15909%] | 437,500,569 | 437,500,569 | 8.4.1 | UN |
| 331 | 8.4.2 | Transformador-Isolating Transformer -ACORDE AL TIPO DE LETRERO |  | 30d | 2022-05-23 | 2022-06-14 | 330SS | 2022-03-27 | 2022-04-21 | 30d | 212d | 0d | Etapa de preconstrucción [303%] | 8,332,654 | 8,332,654 | 8.4.2 | UN |
| 332 | 8.4.3 | Juego de conectores Primarios - 5KV/25A 8SQmm |  | 30d | 2022-06-14 | 2022-07-06 | 331 | 2022-04-21 | 2022-05-13 | 30d | 212d | 0d | Etapa de preconstrucción [41%] | 1,126,037 | 1,126,037 | 8.4.3 | UN |
| 333 | 8.4.4 | Juego de conectores secundarios - FAA L823 12 X 2 Core |  | 30d | 2022-06-14 | 2022-07-06 | 332SS | 2022-04-21 | 2022-05-13 | 30d | 225d |  | Etapa de preconstrucción [54%] | 1,479,929 | 1,479,929 | 8.4.4 | UN |
| 334 | 8.5 | **REGULADORES DE CORRIENTE CONSTANTE INCLUYE CUT OUT Y DESCARGADORES** |  | 1d | 2022-06-14 | 2022-06-15 |  | 2022-04-21 | 2022-04-22 | 1d | 212d |  |  | 419,112,173 | 387,810,434 | 8.5 |  |
| 335 | 8.5.1 | Regulador-CCR (Digital) - 7,5KW, 220V, 60Hz, 6.6A, FAA L829 |  | 1d | 2022-06-14 | 2022-06-15 | 332SS | 2022-04-21 | 2022-04-22 | 1d | 212d | 0d | Etapa de preconstrucción [11260%] | 225,206,956 | 168,905,217 | 8.5.1 | UN |
| 336 | 8.6 | **CABLE Y SISTEMA DE TIERRA** |  | 43d | 2022-06-14 | 2022-07-16 |  | 2022-04-21 | 2022-05-24 | 45d | 212d |  |  | 2,013,390,008 | 2,402,304,736 | 8.6 |  |
| 337 | 8.6.1 | Cable Primario XLPE-TR, 5 KV, No 8 AWG Apantallado |  | 43d | 2022-06-14 | 2022-07-16 | 335SS | 2022-04-21 | 2022-05-24 | 45d | 212d | 0d | Etapa de preconstrucción [17759%] | 578,024,004 | 982,522,412 | 8.6.1 | ML |
| 338 | 8.6.2 | Cable Secundario THHN/THWN-2 CT, 600V, 2 X No 10 AWG |  | 43d | 2022-06-14 | 2022-07-16 | 337SS | 2022-04-21 | 2022-05-24 | 45d | 212d | 0d | Etapa de preconstrucción [4329%] | 171,420,480 | 155,836,800 | 8.6.2 | ML |
| 339 | 8.6.4 | Cable desnudo para puesta a tierra , No. 6 AWG |  | 43d | 2022-06-14 | 2022-07-16 | 338SS | 2022-04-21 | 2022-05-24 | 45d | 212d | 0d | Etapa de preconstrucción [11348%] | 28,371,000 | 28,371,000 | 8.6.4 | ML |
| 340 | 8.6.5 | Varilla para puesta a tierra CU-CU de 5/8 x 2,4 m. Incluye conector |  | 43d | 2022-06-14 | 2022-07-16 | 339SS | 2022-04-21 | 2022-05-24 | 45d | 212d | 0d | Etapa de preconstrucción [2413%] | 5,147,584 | 5,147,584 | 8.6.5 | UN |
| 341 | 8.6.6 | Soldadura exotermica |  | 43d | 2022-06-14 | 2022-07-16 | 340SS | 2022-04-21 | 2022-05-24 | 45d | 212d | 0d | Etapa de preconstrucción [767%] | 1,635,536 | 1,635,536 | 8.6.6 | UN |
| 342 | 8.6.8 | DPS 5 kV marca SINE TRAMER ó equivalente |  | 43d | 2022-06-14 | 2022-07-16 | 341SS | 2022-04-21 | 2022-05-24 | 45d | 212d | 0d | Etapa de preconstrucción [2764%] | 27,639,036 | 27,639,036 | 8.6.8 | UN |
| 343 | 8.7 | **INTEGRACION SIS. CONTROL Y MONITOREO** |  | 40d | 2022-06-14 | 2022-07-14 |  | 2022-04-21 | 2022-05-20 | 40d | 212d |  |  | 1,830,612,942 | 1,830,612,942 | 8.7 |  |
| 344 | 8.7.1 | Sistema Control y Monitoreo de acuerdo a especificación incluye configuración totalidad de balizas y Barras de parada calle LIMA y HOTEL |  | 40d | 2022-06-14 | 2022-07-14 | 342SS | 2022-04-21 | 2022-05-20 | 40d | 212d | 0d | Etapa de preconstrucción [91531%] | 915,306,471 | 915,306,471 | 8.7.1 | GL |
| 345 | 8.8 | **OBRA CIVIL** |  | 43d | 2022-06-14 | 2022-07-16 |  | 2021-08-02 | 2022-05-28 | 394d | 212d |  |  | 1,510,654,614 | 1,114,220,258 | 8.8 |  |
| 346 | 8.8.1 | Ranurado en asfalto y sellamiento tipo 1(1 secundario) |  | 43d | 2022-06-14 | 2022-07-16 | 344SS | 2022-04-21 | 2022-05-24 | 45d | 212d | 0d | Etapa de preconstrucción [7546%] | 139,903,767 | 139,903,767 | 8.8.1 | ML |
| 347 | 8.8.2 | Ranurado en asfalto y sellamiento tipo 2(2 secundarios) |  | 43d | 2022-06-14 | 2022-07-16 | 346SS | 2022-04-21 | 2022-05-24 | 45d | 212d | 0d | Etapa de preconstrucción [15742%] | 27,548,325 | 27,548,325 | 8.8.2 | ML |
| 348 | 8.8.3 | Ranurado en asfalto y sellamiento tipo 3 (3 secundarios) |  | 43d | 2022-06-14 | 2022-07-16 | 347SS | 2022-04-21 | 2022-05-24 | 45d | 212d | 0d | Etapa de preconstrucción [1643%] | 190,578,720 | 190,578,720 | 8.8.3 | ML |
| 349 | 8.8.4 | Ranurado en asfalto y sellamiento tipo 4 (4 secundarios) |  | 43d | 2022-06-14 | 2022-07-16 | 348SS | 2022-04-21 | 2022-05-24 | 45d | 212d | 0d | Etapa de preconstrucción [1808%] | 11,031,728 | 11,031,728 | 8.8.4 | ML |
| 350 | 8.8.7 | Canalización en Zona Verde de 4x4" taxeo |  | 43d | 2022-06-14 | 2022-07-16 | 349SS | 2022-04-21 | 2022-05-28 | 50d | 212d | 0d | Etapa de preconstrucción [53676%] | 511,782,092 | 103,888,800 | 8.8.7 | ML |
| 351 | 8.8.8 | Caja CS 274 de 60cmx60cm |  | 43d | 2022-06-14 | 2022-07-16 | 350SS | 2022-04-21 | 2022-05-24 | 45d | 212d | 0d | Etapa de preconstrucción [14521%] | 34,655,968 | 14,521,084 | 8.8.9 | UN |
| 352 | 8.8.10 | Base en concreto reforzado con accesorios en PVC para conexión eléctrica |  | 43d | 2022-06-14 | 2022-07-16 | 351SS | 2021-08-02 | 2021-09-04 | 45d | 212d | 0d |  | 38,043,885 |  |  | UN |
| 353 | 8.9 | Fin ayudas visuales | milestone | 0d | 2022-07-16 | 2022-07-16 | 344, 352FF | 2022-05-20 | 2022-05-20 | 0d | 212d |  |  |  |  |  |  |

| ID | WBS | Task | Type | Duration | Start | Finish | Predecessors | Baseline start | Baseline finish | Baseline duration | Total slack | Free slack | Resources | Cost | Baseline cost | Text3 | Un |
| --- | --- | --- | --- | --- | --- | --- | --- | --- | --- | --- | --- | --- | --- | --- | --- | --- | --- |
| 354 | 9 | **URBANISMO Y OBRAS DE ARTE** |  | 363d | 2022-03-16 | 2022-12-13 |  | 2022-04-11 | 2022-06-04 | 70d | 10d |  |  | 1,001,140,960 | 871,953,300 |  |  |
| 355 | 9.1 | Vallado |  | 200d | 2022-07-18 | 2022-12-13 | 154SS+100d | 2022-04-21 | 2022-05-24 | 45d | 10d | 0d | Etapa de preconstrucción [9551%] | 55,041,750 | 55,041,750 | 9.1 | ML |
| 356 | 9.2 | Andén en loseta de concreto 30x30 cm |  | 170d | 2022-07-18 | 2022-11-21 | 355SS | 2022-04-21 | 2022-06-04 | 60d | 40d | 30d | Etapa de preconstrucción [34503%] | 301,859,400 | 301,859,400 | 9.2 | M2 |
| 357 | 9.3 | Formación de pradera |  | 100d | 2022-03-16 | 2022-06-01 | 144SS+30d | 2022-04-11 | 2022-06-04 | 70d | 273d | 263d | Etapa de preconstrucción [20826%] | 208,263,160 | 79,075,500 | 9.3 | M2 |
| 358 | 9.4 | Fin Urbanismo y Obras de Arte | milestone | 0d | 2022-12-13 | 2022-12-13 | 355, 356, 357 | 2022-06-04 | 2022-06-04 | 0d | 10d |  |  |  |  |  |  |
| 359 | 10 | **INSTALACIONES PASO A DESNIVEL** |  | 255d | 2022-06-14 | 2022-12-20 |  | 2022-05-19 | 2022-08-10 | 112d | 0d |  |  | 5,866,885,834 | 5,626,763,888 | 10 |  |
| 360 | 10.1 | **SUBESTACION PASO A DESNIVEL** |  | 255d | 2022-06-14 | 2022-12-20 |  | 2022-05-19 | 2022-08-10 | 112d | 0d |  |  | 4,460,194,862 | 4,220,072,916 | 10.1 |  |
| 361 | 10.1.1 | **SUBESTACIÓN ELÉCTRICA NUEVA TORRE DE CONTROL** |  | 80d | 2022-06-14 | 2022-08-12 |  | 2022-05-19 | 2022-07-10 | 70d | 88d |  |  | 71,033,716 | 71,033,716 | 10.1.1 |  |
| 362 | 10.1.1.1 | Celda tipo metalclad normas iec/en o aplicables tal y como son: iec 60439-1/61439, en 60439-1/61439 con salida a cable. para tren de 480 v existente en la subestacion con interruptor tripolar de 200 a. |  | 70d | 2022-06-14 | 2022-08-05 | 185SS+20d | 2022-05-19 | 2022-07-10 | 70d | 88d | 0d | Etapa de preconstrucción [3231%] | 32,305,624 | 32,305,624 | 10.1.1.1 | UN |
| 363 | 10.1.1.2 | Instalación de la celda tipo metalclad, incluye accesorios de conexión, de acuerdo a las recomendaciones del fabricante |  | 70d | 2022-06-22 | 2022-08-12 | 362SS+10d | 2022-05-19 | 2022-07-10 | 70d | 88d | 0d | Etapa de preconstrucción [321%] | 3,211,234 | 3,211,234 | 10.1.1.2 | UN |
| 364 | 10.1.2 | **RED MEDIA TENSION** |  | 235d | 2022-06-29 | 2022-12-20 |  | 2022-05-19 | 2022-06-25 | 50d | 0d |  |  | 434,935,484 | 352,550,832 | 10.1.2 |  |
| 365 | 10.1.2.1 | Acometida 3 x 6 awg xlpe-tr 5 kv pantalla en cinta, nivel de aislamiento 100% |  | 60d | 2022-06-29 | 2022-08-12 | 363SS+10d | 2022-05-19 | 2022-06-25 | 50d | 88d | 0d | Etapa de preconstrucción [12497%] | 124,972,000 | 124,972,000 | 10.1.2.1 | ML |
| 366 | 10.1.2.2 | Terminal premoldeado 5 kv 6 awg uso interior/ exterior | milestone | 0d | 2022-12-20 | 2022-12-20 | 390FF, 238 | 2022-05-19 | 2022-06-25 | 50d | 0d |  | Etapa de preconstrucción |  | 3,943,084 | 10.1.2.2 | JGO |
| 367 | 10.1.2.3 | Centro de transformacion tipo pedestal tipo radial (pad mounted) trifasico 150 kva, 480-277/4160 v. devanados cobre /cobre. incluye protecciones y accesorios |  | 60d | 2022-06-29 | 2022-08-12 | 365SS | 2022-05-19 | 2022-06-25 | 50d | 88d | 0d | Etapa de preconstrucción [2158%] | 107,909,670 | 21,581,934 | 10.1.2.3 | UN |
| 368 | 10.1.2.4 | Centro de transformacion tipo pedestal tipo radial (pad mounted) trifasico 150 kva, 4160/480-277 v. devanados cobre /cobre. incluye protecciones y accesorios |  | 50d | 2022-07-03 | 2022-08-09 | 367SS+5d | 2022-05-19 | 2022-06-25 | 50d | 88d | 0d | Etapa de preconstrucción [2158%] | 21,581,934 | 21,581,934 | 10.1.2.4 | UN |
| 369 | 10.1.2.5 | prueba del cable mt vlf |  | 40d | 2022-07-07 | 2022-08-05 | 368SS+5d | 2022-05-19 | 2022-06-10 | 30d | 88d | 0d | Etapa de preconstrucción [420%] | 4,196,464 | 4,196,464 | 10.1.2.5 | UN |
| 370 | 10.1.3 | **BAJA TENSION** |  | 97d | 2022-07-10 | 2022-09-20 |  | 2022-05-19 | 2022-06-25 | 50d | 88d |  |  | 213,619,124 | 143,877,012 | 10.1.3 |  |
| 371 | 10.1.3.1 | Tablero de distribución general con barraje de fase de 225 a, barraje de neutro de 225 a, barraje de tierra de 225 a, con totalizador de 250 a regulable |  | 50d | 2022-07-10 | 2022-08-16 | 369SS+5d | 2022-05-19 | 2022-06-25 | 50d | 88d | 0d | Etapa de preconstrucción [749%] | 14,989,682 | 7,494,841 | 10.1.3.1 | UN |
| 372 | 10.1.3.2 | Acometida 3 x 4/0 + 1 x 4/0 + 1 x 4/0 awg cu thwn. incluye conectores |  | 50d | 2022-08-12 | 2022-09-19 | 371SS+45d | 2022-05-19 | 2022-06-25 | 50d | 88d | 0d | Etapa de preconstrucción [2537%] | 61,391,649 | 25,368,450 | 10.1.3.2 | ML |
| 373 | 10.1.3.3 | Acometida 3 x 2/0 + 1 x 2/0 + 1 x 2/0 awg cu thwn. incluye conectores |  | 50d | 2022-08-14 | 2022-09-20 | 372SS+2d | 2022-05-19 | 2022-06-25 | 50d | 88d | 0d | Etapa de preconstrucción [643%] | 16,062,700 | 6,425,080 | 10.1.3.3 | ML |
| 374 | 10.1.3.4 | Acometida 3 x 8 + 1 x 8 + 1 8 awg cu thwn. incluye conectores |  | 50d | 2022-08-14 | 2022-09-20 | 373SS | 2022-05-19 | 2022-06-25 | 50d | 88d | 0d | Etapa de preconstrucción [317%] | 12,381,720 | 3,174,800 | 10.1.3.4 | ML |
| 375 | 10.1.3.5 | Tablero de distribucion tipo switchboard autosoportado de12 circuitos, cumpliendo con ensayos y certtificaciones de acuerdo a normas iec 60429 - 1 e iec 61439 1 y 2, ocho interruptores de caja moldeada (30a) instantaneos y totalizador (30 - 50 a regulabl |  | 50d | 2022-08-14 | 2022-09-20 | 374SS | 2022-05-19 | 2022-06-25 | 50d | 88d | 0d | Etapa de preconstrucción [1038%] | 20,755,014 | 10,377,507 | 10.1.3.5 | UN |
| 376 | 10.1.3.6 | Tablero de distribucion tipo switchboard autosoportado de12 circuitos, cumpliendo con ensayos y certificaciones de acuerdo a normas iec 60429 - 1 e iec 61439 1 y 2, cuatro interruptores de caja moldeada (80 - 100 a) instantaneos y totalizador (120 - 150 |  | 50d | 2022-08-14 | 2022-09-20 | 375SS | 2022-05-19 | 2022-06-25 | 50d | 88d | 0d | Etapa de preconstrucción [1310%] | 13,101,878 | 13,101,878 | 10.1.3.6 | UN |
| 377 | 10.1.3.7 | Bandeja portacable 50 cm tipo semipesada, incluye accesorios |  | 50d | 2022-08-14 | 2022-09-20 | 376SS | 2022-05-19 | 2022-06-25 | 50d | 88d | 0d | Etapa de preconstrucción [600%] | 2,997,975 | 5,995,950 | 10.1.3.7 | UN |

| ID | WBS | Task | Type | Duration | Start | Finish | Predecessors | Baseline start | Baseline finish | Baseline duration | Total slack | Free slack | Constraint | Resources | Cost | Baseline cost | Text3 | Un |
| --- | --- | --- | --- | --- | --- | --- | --- | --- | --- | --- | --- | --- | --- | --- | --- | --- | --- | --- |
| 378 | 10.1.4 | **OBRA CIVIL** |  | 34d | 2022-09-20 | 2022-10-15 |  | 2022-06-25 | 2022-08-06 | 57d | 88d |  |  |  | 1,619,929,825 | 1,531,934,644 | 10.1.4 |  |
| 379 | 10.1.4.1 | Cámara cs 276 - camara doble para ducto de 6" |  | 33d | 2022-09-20 | 2022-10-14 | 377 | 2022-06-25 | 2022-07-28 | 45d | 88d | 0d |  | Etapa de preconstrucción [2685%] | 8,949,808 | 26,849,424 | 10.1.4.1 | UN |
| 380 | 10.1.4.2 | Cámara cs 275 - sencilla |  | 33d | 2022-09-20 | 2022-10-14 | 379SS | 2022-06-25 | 2022-07-28 | 45d | 88d | 0d |  | Etapa de preconstrucción [5569%] | 24,503,776 | 55,690,400 | 10.1.4.2 | UN |
| 381 | 10.1.4.3 | Construcción obra civil para subestacion |  | 33d | 2022-09-20 | 2022-10-14 | 380SS | 2022-06-25 | 2022-07-28 | 45d | 88d | 0d |  | Etapa de preconstrucción [18310%] | 183,096,626 | 183,096,626 | 10.1.4.3 | UN |
| 382 | 10.1.4.4 | Cerramiento subestación en tubo galvanizado 2, con malla eslavonada de 1 1/4. puerta. |  | 30d | 2022-09-20 | 2022-10-12 | 381SS | 2022-06-25 | 2022-07-18 | 30d | 88d | 0d |  | Etapa de preconstrucción [2552%] | 25,515,872 | 25,515,872 | 10.1.4.4 | UN |
| 383 | 10.1.4.5 | Suministro tubos ф 6" pvc , tipo tdp para banco ductos ф 6" |  | 34d | 2022-09-20 | 2022-10-15 | 382SS | 2022-06-25 | 2022-08-06 | 57d | 88d | 0d |  | Etapa de preconstrucción [33324%] | 208,277,500 | 333,244,000 | 10.1.4.5 | ML |
| 384 | 10.1.4.6 | Excavación y canalización para banco de ductos 4x6" pvc, tipo tdp areas no pavimento (no incluye suministro tubos pvc ф 6) en zona de anden concretos |  | 32d | 2022-09-20 | 2022-10-14 | 383SS | 2022-06-25 | 2022-08-01 | 50d | 88d | 0d |  | Etapa de preconstrucción [14157%] | 403,618,921 | 141,571,000 | 10.1.4.6 | ML |
| 385 | 10.1.5 | **SISTEMA PUESTA A TIERRA** |  | 35d | 2022-09-20 | 2022-10-16 |  | 2022-06-25 | 2022-08-01 | 50d | 88d |  |  |  | 38,342,332 | 38,342,332 | 10.1.5 |  |
| 386 | 10.1.5.1 | Malla de puesta a tierra |  | 34d | 2022-09-20 | 2022-10-15 | 384SS | 2022-06-25 | 2022-08-01 | 50d | 88d | 0d |  | Etapa de preconstrucción [1826%] | 18,255,540 | 18,255,540 | 10.1.5.1 | ML |
| 387 | 10.1.5.2 | Caja para inspección puesta a tierra |  | 15d | 2022-10-05 | 2022-10-16 | 386SS+20d | 2022-06-25 | 2022-08-01 | 50d | 88d |  |  | Etapa de preconstrucción [92%] | 915,626 | 915,626 | 10.1.5.2 | UN |
| 388 | 10.1.6 | **SISTEMA DE ILUMINACION** |  | 52d | 2022-11-12 | 2022-12-20 |  | 2022-06-25 | 2022-08-10 | 62d | 0d |  |  |  | 675,643,409 | 675,643,408 | 10.1.6 |  |
| 389 | 10.1.6.1 | Sistema de iluminación interior y exterior tipo led para box culvert (paso a desnivel) acorde a especificaciones |  | 52d | 2022-11-12 | 2022-12-20 | 158 | 2022-06-25 | 2022-08-10 | 62d | 0d |  |  | Etapa de preconstrucción [33782%] | 337,821,705 | 337,821,704 | 10.1.6.1 | GL |
| 390 | 10.2 | Fin Instalaciones paso a desnivel | milestone | 0d | 2022-12-20 | 2022-12-20 | 389, 369, 386SS, 387 | 2022-08-10 | 2022-08-10 | 0d | 0d |  |  |  |  |  | Hito |  |
| 391 | 11 | Fin Etapa de construcción | milestone | 0d | 2022-12-20 | 2022-12-20 | 8, 140, 145SS, 159, 358, 390, 353, 292, 264, 223 | 2022-08-10 | 2022-08-10 | 0d | 0d |  |  |  |  |  | Hito |  |
| 392 | 12 | **IVA** |  | 1d | 2022-12-20 | 2022-12-20 |  | 2022-08-10 | 2022-08-10 | 0d | 0.11d |  |  |  | 950,837,046 | 950,837,046 | Hito |  |
| 393 | 12.1 | IVA |  | 1d | 2022-12-20 | 2022-12-20 |  | 2022-08-10 | 2022-08-10 | 0d | 0.11d |  | start no earlier than 2022-12-20 |  | 475,418,523 | 475,418,523 | N/A |  |
| 394 | 12.2 | Fin IVA | milestone | 0d | 2022-12-20 | 2022-12-20 |  | 2022-08-10 | 2022-08-10 | 0d | 1.11d |  | start no earlier than 2022-12-20 |  |  |  | Hito |  |
| 395 | 5 | Fin de obra - entrega final | milestone | 0d | 2022-12-20 | 2022-12-20 | 391FF | 2022-08-10 | 2022-08-10 | 0d | 0d |  | start no earlier than 2022-12-20 | Etapa de preconstrucción |  |  | Hito |  |
